# 3GPP_Release-2000

Schedule from MS Project, 2000-01-03 to 2007-09-15, A marks actual dates.

## Calendars

- Standard: Mon-Fri 08:00-12:00, 13:00-17:00; Sat-Sun off.

## Resources

| Resource |
| --- |
| NP |
| N1 |
| N2 |
| N3 |
| N4 |
| N5 |
| TP |
| T1 |
| T2 |
| T3 |
| RP |
| R1 |
| R2 |
| R3 |
| R4 |
| SP |
| S1 |
| S2 |
| S3 |
| S4 |
| S5 |
| PCG |
| GP |
| No |
| CN4 |
| ? |
| WG G2 |
| G2 |
| G1 |
| G4 |
| G3 |
| All |
| Generic |
| MLST |
| G5 |
| S3; G2 |
| WG T2 |
| GP;G1 |
| G4;G5 |
| OMA |
| GP-G2 |
| Yes |
| GP; |
| N4; |
| GP; N1 |
| CT5 |
| C5 |
| C1 |
| C4 |
| C3 |
| C6 |
| G1; |
| 4 |
| ct |
| c;s;r |
| CT;RAN;SA |

## Schedule

| ID | WBS | Task | Type | Duration | Start | Finish | Complete | Remaining | Baseline start | Baseline finish | Baseline duration | Total slack | Constraint | Resources | Work | Actual work | Text9 | Text6 | Text1 | Text4 | Text5 | Text7 | Text8 |
| --- | --- | --- | --- | --- | --- | --- | --- | --- | --- | --- | --- | --- | --- | --- | --- | --- | --- | --- | --- | --- | --- | --- | --- |
| 1 | 1 | VERSION 2006 March 22nd |  | 1d | 2000-01-03 | 2000-01-03 |  |  | 2000-01-03 | 2000-01-03 | 1d | 1839d |  |  |  |  | 2044 |  |  |  |  |  |  |
| 2 | 2 | "CTRL + a" to display all the 3GPP fields |  | 1d | 2000-01-03 | 2000-01-03 |  |  | 2000-01-03 | 2000-01-03 | 1d | 1839d |  |  |  |  | 1462 |  |  |  |  |  |  |
| 3 | 3 | Content of Release 7, not frozen |  | 1d | 2000-01-03 | 2000-01-03 |  |  | 2000-01-03 | 2000-01-03 | 1d | 1839d |  |  |  |  | 2058 |  |  |  |  |  |  |
| 5 | 4 | Rel-7 Features listed below |  | 1d? | 2000-01-03 | 2000-01-03 |  |  | 2000-01-03 | 2000-01-03 | 1d? | 1839d |  | CT;RAN;SA | 8h |  |  | Rel-7 |  |  |  |  |  |
| 6 | 8.5 | **Multiple Input Multiple Output antennas (MIMO)** |  | 850d? | 2003-03-14 A | 2006-06-15 | 17% | 707.36d? | 2003-03-14 | 2005-12-15 | 720d? | 326d |  | R1 | 30360h | 6052.8h | 2468 | Rel-7 | MIMO | Howard Huang, Lucent | hchuang@lucent.com | TSG | Cesar |
| 7 | 5.1 | MIMO - Physical layer |  | 720d? | 2003-09-12 A | 2006-06-15 | 65% | 252d? | 2003-09-12 | 2005-12-15 | 590d? | 156d | finish no earlier than 2006-06-15 | R1 | 5760h | 3744h |  | Rel-7 | MIMO-Phys | Howard Huang, Lucent | hchuang@lucent.com | TSG | MCC_RAN |
| 8 | 5.2 | MIMO - Layer 2,3 aspects |  | 720d? | 2003-09-12 | 2006-06-15 |  |  | 2003-09-12 | 2005-12-15 | 589d? | 156d | finish no earlier than 2006-06-15 | R2 | 5760h |  |  | Rel-7 | MIMO-L23 | Howard Huang, Lucent | hchuang@lucent.com | TSG | MCC_RAN |
| 9 | 5.3 | MIMO - Iub/Iur Protocol Aspects |  | 850d? | 2003-03-14 | 2006-06-15 |  |  | 2003-03-14 | 2005-12-15 | 719d? | 156d | finish no earlier than 2006-06-15 | R3 | 6800h |  |  | Rel-7 | MIMO-IurIub | Howard Huang, Lucent | hchuang@lucent.com | TSG | MCC_RAN |
| 10 | 5.4 | MIMO - RF Radio Transmission/Reception, System Performance Requirements and Conformance Testing |  | 655d? | 2003-12-12 A | 2006-06-15 | 4% | 628.8d? | 2003-12-12 | 2005-12-15 | 524d? | 156d | finish no earlier than 2006-06-15 | R4 | 5240h | 209.6h |  | Rel-7 | MIMO-RF | Man Hung Ng, Lucent | ngm@lucent.com | TSG | MCC_RAN |
| 11 | 6 | **Rel-7 Improvements of the Radio Interface** |  | 588d? | 2004-09-15 A | 2006-12-15 | 59% | 242.97d? | 2004-09-15 | 2006-06-15 | 456d? | 195d |  | RP | 23528h | 12954.8h |  | Rel-7 | RInImp |  |  |  | Cesar |
| 12 | 6.1 | Extended UMTS 1.7/2.1 GHz |  | 198d? | 2006-03-15 | 2006-12-15 |  |  |  |  |  | 195d | finish no earlier than 2006-12-15 | R4 | 1584h |  |  | Rel-7 | RInImp-UMTS1721Ext | Johan Sköld | johan.skold@ericsson.com |  | MCC_RAN |
| 13 | 6.2 | UMTS 2.6 GHz |  | 195d? | 2004-09-15 A | 2005-06-14 A | 100% |  | 2004-09-15 | 2005-06-14 | 195d? |  | finish no earlier than 2005-06-14 | R4 | 1560h | 1560h |  | Rel-7 | RInImp-UMTS2600 | Jussi Numminen, Nokia | jussi.numminen@nokia.com | TSG | Cesar |
| 14 | 6.3 | UMTS 2.6 GHz TDD |  | 261d? | 2004-12-15 A | 2005-12-14 A | 100% |  | 2004-12-15 | 2005-12-15 | 261d? |  | finish no earlier than 2005-12-15 | R4 | 2088h | 2088h |  | Rel-7 | RInImp-UMTS2600TDD | Shin Horng Wong (IPWireless) | shwong@IPWIRELESS.COM | TSG | MCC_RAN |
| 15 | 6.4 | UMTS 900 MHz |  | 261d? | 2004-12-15 A | 2005-12-14 A | 100% |  | 2004-12-15 | 2005-12-15 | 261d? |  | finish no earlier than 2005-12-15 | R4 | 2088h | 2088h |  | Rel-7 | RInImp-UMTS900 | Yannick Li (Nortel) | yli@nortelnetworks.com | TSG | MCC_RAN |
| 16 | 6.5 | UMTS 1700 MHz |  | 197d? | 2005-03-15 A | 2005-12-14 A | 100% |  | 2005-03-15 | 2005-12-15 | 197d? |  | finish no earlier than 2005-12-15 | R4 | 1576h | 1576h |  | Rel-7 | RInImp-UMTS1700 | Takehiro Nakamura | NTT DoCoMo | TSG | MCC_RAN |
| 17 | 6.6 | Pending decision of the PCG!! UMTS 2.6 GHz FDD DL External |  | 195d? | 2005-09-15 | 2006-06-15 |  |  | 2005-09-15 | 2006-06-15 | 195d? | 157d | finish no earlier than 2006-06-15 | R4 | 1560h |  |  | Rel-7 | RInImp-UMTS2600Ext | Han van Bussel | han.van.bussel@t-mobile.de | TSG | MCC_RAN |
| 18 | 6.7 | UE Antenna Performance Evaluation Method and Requirements |  | 392d? | 2004-12-15 A | 2006-06-15 | 65% | 137.2d? | 2004-12-15 | 2006-03-15 | 325d? | 326d | finish no earlier than 2006-06-15 | R4 | 3136h | 2038.4h |  | Rel-7 | RInImp-UEAnt | Christian Bergljung (TeliaSonera) | Christian.Bergljung@TeliaSonera.com | TSG | MCC_RAN |
| 19 | 6.8 | Improved Performance Requirements for HSDPA UE based on Rx Diversity (type 1) & LMMSE equalizer (type 2) | milestone | 0d? | 2005-03-15 A | 2005-03-15 A | 100% |  | 2005-03-15 | 2005-03-15 | 0d? |  | finish no earlier than 2005-03-15 | R4 |  |  |  | Rel-7 | RInImp-HSPerf-Type3 | Marc Grant | marc.grant@cingular.com | TSG | MCC_RAN |
| 20 | 6.9 | **Additional minimum UE performance requirement for non-HSDPA channels based on type 1 enhanced receiver (Rx Diversity)** |  | 195d? | 2005-09-15 A | 2006-06-15 | 49% | 98.49d? |  |  |  | 327d |  | R4 | 3136h | 1552.08h |  | Rel-7 | RInImp-RxDiv | Serge Willenegger | sergew@qualcomm.com |  | MCC_RAN |
| 21 | 6.9.1 | Additional minimum UE performance requirement for DL physical channels in support of DCH/HS-DSCH operation based on type 1 enhanced receiver (RX-Diversity) |  | 195d? | 2005-09-15 A | 2006-06-15 | 50% | 97.5d? | 2005-09-15 | 2006-06-15 | 195d? | 327d | finish no earlier than 2006-06-15 | R4 | 1560h | 780h |  | Rel-7 | RInImp-RxDiv-DCH | Marc Grant | marc.grant@cingular.com | TSG | MCC_RAN |
| 22 | 6.9.2 | Additional minimum UE performance requirement for downlink physical channels in support of MTCH and MCCH operation based on type 1 enhanced receiver (Rx-Diversity) |  | 1d? | 2006-03-15 | 2006-03-15 |  |  |  |  |  | 392d | start no earlier than 2006-03-15 | R4 | 8h |  |  | Rel-7 | RInImp-RxDiv-MBMS | Serge Willenegger | sergew@qualcomm.com |  | MCC_RAN |
| 23 | 6.9.3 | Additional minimum UE performance requirement for downlink physical channels in support of E-DCH operation based on type 1 enhanced receiver (Rx-Diversity) |  | 1d? | 2006-03-15 | 2006-03-15 |  |  |  |  |  | 392d | start no earlier than 2006-03-15 | R4 | 8h |  |  | Rel-7 | RInImp-RxDiv-EDCH | Serge Willenegger | sergew@qualcomm.com |  | MCC_RAN |
| 24 | 6.10 | Improved support of gaming over HSDPA/EDCH |  | 262d? | 2005-12-15 | 2006-12-15 |  |  |  |  |  | 25d | finish no earlier than 2006-12-15 | R2 | 2096h |  |  | Rel-7 | RInImp-Gaming | Don Zelmer, Cingular | don.zelmer@cingular.com |  | MCC_RAN |
| 25 | 7 | **7.68Mcps TDD option** |  | 457d? | 2004-09-15 A | 2006-06-15 | 93% | 33.07d? | 2004-09-15 | 2006-06-15 | 456d? | 326d |  | RP | 19824h | 16376.2h |  | Rel-7 | VHCRTDD | Martin Beale, IPWireless | mbeale@ipwireless.com | TSG | Cesar |
| 26 | 7.1 | VHCRTDD: Stage 2 |  | 391d? | 2004-09-15 A | 2006-03-15 A | 100% |  | 2004-09-15 | 2005-12-15 | 326d? |  | finish no earlier than 2006-03-15 | R1 | 3128h | 3128h |  | Rel-7 | VHCRTDD-Stage2 | Martin Beale, IPWireless | mbeale@ipwireless.com | TSG | MCC_RAN |
| 27 | 7.2 | VHCRTDD: Physical Layer |  | 391d? | 2004-09-15 A | 2006-03-15 A | 100% |  | 2004-09-15 | 2005-12-15 | 326d? |  | finish no earlier than 2006-03-15 | R1 | 3128h | 3128h |  | Rel-7 | VHCRTDD-Phys | Martin Beale, IPWireless | mbeale@ipwireless.com | TSG | MCC_RAN |
| 28 | 7.3 | VHCRTDD: Layer 2 and layer 3 protocol aspects |  | 391d? | 2004-09-15 A | 2006-03-15 A | 100% |  | 2004-09-15 | 2005-12-15 | 326d? |  | finish no earlier than 2006-03-15 | R2 | 3128h | 3128h |  | Rel-7 | VHCRTDD-L23 | Derek Richards, IPWireless | drichards@ipwireless.com | TSG | MCC_RAN |
| 29 | 7.4 | VHCRTDD: UTRAN Iub/Iur Protocol Aspects |  | 391d? | 2004-09-15 A | 2006-03-15 A | 100% |  | 2004-09-15 | 2005-12-15 | 326d? |  | finish no earlier than 2006-03-15 | R3 | 3128h | 3128h |  | Rel-7 | VHCRTDD-IurIub | Peter Legg, IPWireless | plegg@ipwireless.com | TSG | MCC_RAN |
| 30 | 7.5 | VHCRTDD: RF Radio Transmission/ Reception, System Performance Requirements and Conformance Testing |  | 457d? | 2004-09-15 A | 2006-06-15 | 68% | 146.24d? | 2004-09-15 | 2006-06-15 | 456d? | 326d | finish no earlier than 2006-06-15 | R4 | 3656h | 2486.08h |  | Rel-7 | VHCRTDD-RF | Shin Horng Wong | shwong@ipwireless.com | TSG | MCC_RAN |

Notes:
- 6: Text3: TR25.876,TR25.996
- 7: Text3: 25.211, 25.212, 25.213, 25.214, 25.215, 25.221, 25
- 8: Text3: TR 25.876
- 12: Text3: 25.806, 25.101, 25.104, 25.133, 24.141, 25.331, 25.306, 25.307, 25.423, 25.461, 25.463, 34.121
- 13: Approved at RP#25 as RP-040377 / Text3: TS25.101, TS25.104, TS25.133, TS25.141, TS25.331, TS25.942, TS25.306, TS25.307, TS34.121
- 14: Text3: 25.102, 25.105, 25.113, 25.123, 25.142, 25.331, 25.942, 25.306, 25.307, 34.122, 34.124
- 15: Text3: 25.101, 25.104, 25.113, 25.133, 25.141, 25.331, 25.942, 25.306, 25.307, 34.121
- 16: Text3: 25.101, 25.104, 25.113, 25.133, 25.141, 25.306, 25.307, 25.331, 34.121
- 17: Text3: 25.101, 25.104, 25.133, 25.141, 25.331, 25.942, 25.306, 25.307, 34.121
- 18: Text3: TS25.101
- 19: Text3: 25.101
- 21: Text3: 25.101
- 22: Text3: 25.101
- 23: Text3: 25.101
- 25: Approved at RP#25 as RP-040365
- 26: Text3: TS25.202
- 27: Text3: TS25.221, TS25.222, TS25.223, TS25.224,TS25.225
- 28: Text3: TS25.301, TS25.302, TS25.305, TS25.306, TS25.321, TS25.331
- 29: Text3: TS25.401, TS25.420, TS25.423, TS25.425, TS25.427, TS25.430, TS25.433, TS25.435
- 30: Text3: TS25.102, TS25.105, TS25.123, TS25.133, TS25.142

| ID | WBS | Task | Duration | Start | Finish | Complete | Remaining | Baseline start | Baseline finish | Baseline duration | Total slack | Constraint | Resources | Work | Actual work | Text1 | Text6 | Text7 | Text8 | Text4 | Text5 | Text2 | Text9 |
| --- | --- | --- | --- | --- | --- | --- | --- | --- | --- | --- | --- | --- | --- | --- | --- | --- | --- | --- | --- | --- | --- | --- | --- |
| 31 | 8 | **Rel-7 RAN improvements** | 523d? | 2004-12-15 A | 2006-12-15 | 47% | 277.5d? | 2004-12-15 | 2006-03-15 | 325d? | 195d |  | RP | 16816h | 6622.05h | RANimp | Rel-7 | TSG | MCC_RAN |  |  |  |  |
| 32 | 8.1 | Optimisation of channelisation code utilisation for 1.28 Mcps TDD | 392d? | 2004-12-15 A | 2006-06-15 | 85% | 58.8d? | 2004-12-15 | 2005-12-15 | 261d? | 326d | finish no earlier than 2006-06-15 | R1 | 3136h | 2665.6h | RANimp-RABSE-CodOptLCRTDD | Rel-7 | TSG | MCC_RAN | Ka Leong Lo | kaleong.lo@utstar.com |  |  |
| 33 | 8.2 | Delay optimisation for procedures applicable to CS and PS Connections | 394d? | 2005-03-15 A | 2006-09-15 | 40% | 236.4d? | 2005-03-15 | 2006-03-15 | 261d? | 260d | finish no earlier than 2006-09-15 | R2 | 3152h | 1260.8h | RANimp-DelayOpt | Rel-7 | TSG | MCC_RAN | Juho Pirskanen | juho.pirskanen@nokia.com |  |  |
| 34 | 8.3 | UE Performance Requirements for MBMS (TDD) | 328d? | 2005-03-15 A | 2006-06-15 | 60% | 131.2d? | 2005-03-15 | 2006-03-15 | 261d? | 326d | finish no earlier than 2006-06-15 | R4 | 2624h | 1574.4h | MBMS-RAN-RF-TDD | Rel-7 | TSG | MCC_RAN | Shin Horng Wong | shwong@ipwireless.com |  |  |
| 35 | 8.4 | Continuous connectivity for packet data users | 134d? | 2005-03-14 A | 2005-09-15 | 40% | 80.4d? | 2005-03-14 | 2005-03-15 | 1d? | 521d | finish no earlier than 2005-09-15 | R1 | 1072h | 428.8h | RANimp-ConCon | Rel-7 | TSG | MCC_RAN | Joern Krause | Joern.Krause@siemens.com |  |  |
| 36 | 8.5 | Extended WCDMA Cell Range | 133d? | 2006-03-15 | 2006-09-15 |  |  |  |  |  | 260d | finish no earlier than 2006-09-15 | R3 | 1064h |  | RANimp-ExtCell | Rel-7 |  | MCC_RAN | Ericsson |  |  |  |
| 37 | 8.6 | 7.68 Mcps TDD Enhanced Uplink | 198d? | 2006-03-15 | 2006-12-15 |  |  |  |  |  | 195d | finish no earlier than 2006-12-15 | R1 | 1584h |  | RANimp-VHCRTDD-EDCH | Rel-7 |  | MCC_RAN | Nicholas Anderson | nanderson@ipwireless.com |  |  |
| 38 | 9 | **3.84 Mcps TDD Enhanced Uplink** | 394d? | 2005-03-15 A | 2006-09-15 | 49% | 201.42d? | 2005-03-15 | 2006-06-15 | 327d? | 260d |  | RP | 17328h | 7360.03h | EDCHTDD | Rel-7 | TSG | MCC_RAN | Nicholas Anderson | nanderson@ipwireless.com |  |  |
| 39 | 9.1 | EDCHTDD: Stage 2 | 328d? | 2005-03-15 A | 2006-06-15 | 70% | 98.4d? | 2005-03-15 | 2005-12-14 | 197d? | 326d | finish no earlier than 2006-06-15 | R2 | 2624h | 1836.8h | EDCHTDD-Stage2 | Rel-7 | TSG | MCC_RAN | Nicholas Anderson | nanderson@ipwireless.com |  |  |
| 40 | 9.2 | EDCHTDD: Physical Layer | 328d? | 2005-03-15 A | 2006-06-15 | 70% | 98.4d? | 2005-03-15 | 2006-03-14 | 261d? | 326d | finish no earlier than 2006-06-15 | R1 | 2624h | 1836.8h | EDCHTDD-Phys | Rel-7 | TSG | MCC_RAN | Nicholas Anderson | nanderson@ipwireless.com |  |  |
| 41 | 9.3 | EDCHTDD: Layer 2 and 3 Protocol Aspects | 328d? | 2005-03-15 A | 2006-06-15 | 70% | 98.4d? | 2005-03-15 | 2006-03-14 | 261d? | 326d | finish no earlier than 2006-06-15 | R2 | 2624h | 1836.8h | EDCHTDD-L23 | Rel-7 | TSG | MCC_RAN | Derek Richards | drichards@ipwireless.com |  |  |
| 42 | 9.4 | EDCHTDD: UTRAN Iub/Iur Protocol Aspects | 394d? | 2005-03-15 A | 2006-09-15 | 25% | 295.5d? | 2005-03-15 | 2006-03-14 | 261d? | 260d | finish no earlier than 2006-09-15 | R3 | 3152h | 788h | EDCHTDD-IurIub | Rel-7 | TSG | MCC_RAN | Jim Miller | jim.miller@interdigital.com |  |  |
| 43 | 9.5 | EDCHTDD: RF Radio Transmission/ Reception, System Performance Requirements and Conformance Testing | 394d? | 2005-03-15 A | 2006-09-15 | 20% | 315.2d? | 2005-03-15 | 2006-06-15 | 327d? | 260d | finish no earlier than 2006-09-15 | R4 | 3152h | 630.4h | EDCHTDD-RF | Rel-7 | TSG | MCC_RAN | Shin Horng Wong | shwong@ipwireless.com |  |  |
| 44 | 10 | **1.28 Mcps TDD Enhanced Uplink** | 262d? | 2006-03-15 | 2007-03-15 |  |  |  |  |  | 131d |  | RP | 8944h |  | LCRTDD-EDCH | Rel-7 |  | MCC_RAN | Haijing Hu (CATT) |  |  |  |
| 45 | 10.1 | 1.28 Mcps TDD Enhanced Uplink: Physical Layer | 198d? | 2006-03-15 | 2006-12-15 |  |  |  |  |  | 195d | finish no earlier than 2006-12-15 | R1 | 1584h |  | LCRTDD-EDCH-Phys | Rel-7 |  | MCC_RAN | Ke Wang (CATT) |  |  |  |
| 46 | 10.2 | 1.28 Mcps TDD Enhanced Uplink: Layer 2 and 3 Protocol Aspects | 198d? | 2006-03-15 | 2006-12-15 |  |  |  |  |  | 195d | finish no earlier than 2006-12-15 | R2 | 1584h |  | LCRTDD-EDCH-L23 | Rel-7 |  | MCC_RAN | Haiyang Quan (CATT) |  |  |  |
| 47 | 10.3 | 1.28 Mcps TDD Enhanced Uplink: UTRAN Iub/Iur Protocol Aspects | 198d? | 2006-03-15 | 2006-12-15 |  |  |  |  |  | 195d | finish no earlier than 2006-12-15 | R3 | 1584h |  | LCRTDD-EDCH-IubIur | Rel-7 |  | MCC_RAN | Yincheng Zhang (CATT) |  |  |  |
| 48 | 10.4 | 1.28 Mcps TDD Enhanced Uplink: RF Radio Transmission/ Reception, System Performance Requirements and Conformance Testing | 262d? | 2006-03-15 | 2007-03-15 |  |  |  |  |  | 131d | finish no earlier than 2007-03-15 | R4 | 2096h |  | LCRTDD-EDCH-RF | Rel-7 |  | MCC_RAN | Yuexia Song (CATT) |  |  |  |
| 49 | 11 | **PS domain and IMS impacts for supporting IMS Emergency calls** | 1565d? | 2000-09-18 A | 2006-09-15 | 74% | 405.22d? | 2000-08-14 | 2006-06-09 | 1520d? | 260d |  | S2 | 38037h | 27340.8h | EMC1 | Rel-7 | TSG | Maurice | Rainer Liebhart |  |  |  |
| 50 | 10.1.1 | Service Requirements for IP-based emergency calls | 985d | 2000-09-18 A | 2004-06-25 A | 100% |  | 2000-09-18 | 2004-06-25 | 985d |  | finish no earlier than 2004-06-25 | S1 | 7880h | 7880h | EMC1 | Rel-7 |  |  |  |  | CCaR | 1314 |
| 51 | 11.2 | Study on Stage 2 for IMS-level solution | 668d? | 2003-02-26 A | 2005-09-16 A | 100% |  | 2003-02-26 | 2005-09-16 | 668d? |  | finish no earlier than 2005-09-16 | S2 | 5344h | 5344h | EMC1 | Rel-7 | TSG |  | Rainer Liebhart, Siemenws |  |  |  |
| 52 | 11.3 | Study on Stage 2 for GPRS-level solution | 301d? | 2004-10-14 A | 2005-12-08 A | 100% |  | 2004-10-14 | 2005-12-08 | 301d? |  | finish no earlier than 2005-12-08 | S2 | 2408h | 2408h | EMC1 | Rel-7 |  |  |  |  |  |  |
| 53 | 11.4 | Stage 2 Specification Phase - IMS-level | 200d? | 2005-09-05 A | 2006-06-09 | 64% | 72d? | 2005-09-05 | 2006-06-09 | 200d? | 330d | finish no earlier than 2006-06-09 | S2 | 1600h | 1024h | EMC1 | Rel-7 |  |  |  |  |  |  |
| 54 | 11.5 | Stage 2 Specification Phase - GPRS-level | 200d? | 2005-09-05 A | 2006-06-09 | 64% | 72d? | 2005-09-05 | 2006-06-09 | 200d? | 330d | finish no earlier than 2006-06-09 | S2 | 1600h | 1024h | EMC1 | Rel-7 |  |  |  |  |  |  |

Notes:
- 31: Generic feature
- 33: Text3: TS25.321, TS25.322, TS25.331
- 34: Text3: TS25.102, TS25.123
- 36: Text3: 25.133, 25.423, 25.425, 25.433, 25.435, 25.453, 25.331
- 37: Text3: 25.201, 25.202, 25.221, 25.222, 25.223, 25.224, 25.225, 25.331, 23.321, 25.306, 25.302, 25.401, 25.420, 25.423, 25.427, 25.433, 25.102, 25.105, 25.142
- 40: Text3: TS25.201, TS25.221,TS25.222, TS25.223, TS25.224, TS25.225
- 41: Text3: TS25.301, TS25.302, TS25.306, TS25.321, TS25.331
- 42: Text3: TS25.401, TS25.420, TS25.423, TS25.427, TS25.430, TS25.433, TS25.435
- 43: Text3: TS25.102, TS25.105, TS25.123, TS25.142
- 45: Text3: 25.201, 25.221, 25.222, 25.223, 25.224, 25.225
- 46: Text3: 25.301, 25.302, 25.306, 25.321, 25.331
- 47: Text3: 25.401, 25.420, 25.423, 25.425, 25.427, 25.430, 25.433, 25.435
- 48: Text3: 25.102, 25.105, 25.123, 25.142
- 50: Text3: 22.976
- 51: Text3: 23.228, 23.060, 23.002

| ID | WBS | Task | Type | Duration | Start | Finish | Complete | Remaining | Baseline start | Baseline finish | Baseline duration | Total slack | Constraint | Resources | Work | Actual work | Text1 | Text2 | Text5 | Text6 | Text9 | Text3 | Text7 | Text8 | Text12 |
| --- | --- | --- | --- | --- | --- | --- | --- | --- | --- | --- | --- | --- | --- | --- | --- | --- | --- | --- | --- | --- | --- | --- | --- | --- | --- |
| 55 | 10.1 | **Emergency Call Enhancements for IP& PS Based Calls – stage 3** |  | 180d | 2006-01-09 A | 2006-09-15 | 6% | 169.7d | 2000-08-14 | 2005-07-11 | 1280.1d | 260d |  | C1 | 6684.96h | 382.55h | EMC1 | CCaR | alf.heidermark@ericsson.com | Rel-7 | 1653 |  |  |  |  |
| 56 | 10.1.2 | CT1 IMS aspects to support IMS Emergency sessions |  | 155.82d | 2006-01-09 A | 2006-09-15 | 25% | 116.86d | 2000-10-17 | 2005-07-08 | 1209d | 260d | finish no earlier than 2006-09-15 | C1 | 1246.56h | 311.64h | EMC1 | CCaR | Atle.Monrad@eto.ericsson.se | Rel-7 | 1315 | 24.229 |  |  |  |
| 57 | 10.1.2 | CT3 IMS aspects to support IMS Emergency sessions |  | 95d | 2006-05-08 | 2006-09-15 |  |  | 2000-10-17 | 2005-07-08 | 1209d | 260d | finish no earlier than 2006-09-15 | C3 | 760h |  | EMC1 | CCaR | Atle.Monrad@eto.ericsson.se | Rel-7 | 1315 | 29.613 |  |  |  |
| 58 | 10.1.5 | CT1 PS domain aspects to support IMS Emergency sessions |  | 154.9d | 2006-01-09 | 2006-09-15 |  |  | 2000-08-14 | 2005-07-11 | 1255d | 260d | start no earlier than 2006-01-09 | C1 | 1239.2h |  | EMC1 | CCaR | Atle.Monrad@eto.ericsson.se | Rel-7 | 1646 | 24.008 |  |  |  |
| 59 | 10.1.5 | CT3 PS domain aspects to support IMS Emergency sessions |  | 95d | 2006-05-08 | 2006-09-15 |  |  | 2000-08-14 | 2005-07-11 | 1255d | 260d | start no earlier than 2006-05-08 | C3 | 760h |  | EMC1 | CCaR | Atle.Monrad@eto.ericsson.se | Rel-7 | 1646 | 29.061 |  |  |  |
| 60 | 10.1.5 | CT4 PS domain aspects to support IMS Emergency sessions |  | 180d | 2006-01-09 | 2006-09-15 |  |  | 2000-08-14 | 2005-07-11 | 1255d | 260d | start no earlier than 2006-01-09 | C4 | 1440h |  | EMC1 | CCaR | Atle.Monrad@eto.ericsson.se | Rel-7 | 1646 | 29.060 |  |  |  |
| 61 | 12 | **Access Class Barring and Overload Protection** |  | 492d? | 2004-03-15 A | 2006-01-31 | 50% | 244.33d? | 2004-03-15 | 2005-11-18 | 440d? | 423d |  | S2 | 11024h | 5549.33h | ACBOP |  |  | Rel-7 |  | 23.898 | TSG | Maurice |  |
| 62 | 12.1 | TR on Stage 2 |  | 274d? | 2004-03-15 A | 2005-03-31 A | 100% |  | 2004-03-15 | 2005-03-31 | 274d? |  | finish no earlier than 2005-03-31 | S2 | 2192h | 2192h | ACBOP |  |  | Rel-7 |  |  | TSG |  |  |
| 63 | 12.2 | Extra ACBOP information in GERAN |  | 440d? | 2004-03-15 | 2005-11-18 |  |  | 2004-03-15 | 2005-11-18 | 440d? | 475d | finish no earlier than 2005-11-18 | GP | 3520h |  | ACBOP |  |  | Rel-7 |  | 44.018 | TSG | Gert |  |
| 64 | 12.3 | Stage 3 CN aspects of ACBOP |  | 172d? | 2005-06-06 A | 2006-01-31 A | 100% |  | 2004-12-08 | 2004-12-08 | 1d? |  | start no earlier than 2005-06-06 | C1 | 1376h | 1376h | ACBOP |  |  | Rel-7 |  | 24.008 |  |  |  |
| 65 | 12.4 | Deleted - Potential impact on Iu interface Overload functionality | milestone | 0d? | 2004-03-15 A | 2004-03-15 A | 100% |  | 2004-03-15 | 2004-03-15 | 0d? |  | finish no earlier than 2004-03-15 | RP |  |  | ACBOP |  |  | Rel-7 |  | 25.413 |  |  | RP-25 |
| 66 | 12.5 | Deleted - Extra ACBOP information in RAN | milestone | 0d? | 2004-03-15 A | 2004-03-15 A | 100% |  | 2004-03-15 | 2004-03-15 | 0d? |  | finish no earlier than 2004-03-15 | RP |  |  | ACBOP |  |  | Rel-7 |  | 25.331 |  |  | RP-25 |
| 67 | 13 | **USSD message delivery and transfer to USIM** |  | 376d? | 2004-03-05 A | 2005-08-12 A | 100% |  | 2004-03-05 | 2005-11-16 | 443.7d? |  |  | S1 | 5698.4h | 5698.4h | USSD-USIM |  |  | Rel-7 |  | 22.090 | TSG | Michael |  |
| 68 | 13.1 | Stage 1 |  | 152d? | 2004-03-18 A | 2004-10-15 A | 100% |  | 2004-03-18 | 2004-10-15 | 152d? |  | start no earlier than 2004-03-18 | S1 | 1216h | 1216h | USSD-USIM |  |  | Rel-7 |  | 22.090 | TSG | Michael |  |
| 69 | 13.2 | Alignment with requirements regarding USSD usage |  | 193.3d? | 2004-03-05 A | 2005-08-12 A | 100% |  | 2004-03-05 | 2005-11-16 | 261d? |  | finish no earlier than 2005-08-12 | C6 | 1546.4h | 1546.4h | USSD-USIM |  | cdubois@axalto.com | Rel-7 |  |  | TSG |  |  |
| 70 | 14 | **Location Services enhancements Rel-7** |  | 655d? | 2004-06-28 A | 2006-12-29 | 61% | 254.18d? | 2004-06-28 | 2006-08-25 | 565d? | 185d |  | S2 | 29661.6h | 15521.4h | LCS3 |  |  | Rel-7 |  | 23.271 |  | Maurice |  |
| 71 | 14.1 | Global Stage 2 for LCS3 (including IMS emergency location aspects) |  | 321d? | 2004-12-31 A | 2006-03-24 | 95% | 17d? | 2004-12-31 | 2006-03-24 | 321d? | 385d | finish no earlier than 2006-03-24 | S2 | 2568h | 2432h | LCS3 |  | brodilitz@sirf.com | Rel-7 |  | 23.271 | TSG | Maurice |  |
| 72 | 14.2 | CT4 aspects for LCS |  | 66d? | 2006-01-02 A | 2006-04-03 | 60% | 26.4d? | 2005-03-15 | 2005-06-15 | 66d? | 379d | start no earlier than 2006-01-01 | C4 | 528h | 316.8h | LCS3-UEPos-LBS |  |  | Rel-7 |  |  | TSG |  |  |
| 73 | 14.3 | **LCS for 3GPP Interworking WLAN** |  | 655d? | 2004-06-28 A | 2006-12-29 | 59% | 268.59d? | 2004-06-28 | 2006-08-25 | 565d? | 185d |  | S1 | 10741.6h | 3344h | LCS3-IWLAN |  |  | Rel-7 |  | 22.935 | TSG | Michael |  |
| 74 | 14.3.1 | FS on 3GPP system to WLAN Interworking with LCS |  | 512.7d? | 2004-06-28 A | 2006-06-30 | 79% | 107d? | 2004-06-28 | 2005-09-29 | 316.7d? | 315d | finish no earlier than 2005-09-29 | S1 | 4101.6h | 3245.6h | LCS3-IWLAN |  |  | Rel-7 |  | 22.935 |  |  |  |
| 75 | 14.3.2 | Stage 2 work on an LCS architecture for I-WLAN. |  | 175d? | 2006-05-01 | 2006-12-29 |  |  |  |  |  | 185d | start no earlier than 2006-05-01 | S2 | 1400h |  | LCS3-IWLAN |  | dhshim@lge.com ; phede@lge.com | Rel-7 |  | 23.8yz |  | Maurice |  |
| 76 | 14.4 | **UE positioning Rel-7** |  | 456d? | 2004-09-15 A | 2006-06-15 | 80% | 91.2d? | 2004-09-15 | 2006-06-15 | 456d? | 327d |  | RP | 7296h | 5629.24h | LCS3-UEpos |  |  | Rel-7 |  |  | TSG | Cesar |  |
| 77 | 14.4.1 | Inclusion of Uplink TDOA UE positioning method in the UTRAN specifications |  | 456d? | 2004-09-15 A | 2006-06-15 | 80% | 91.2d? | 2004-09-15 | 2006-06-15 | 456d? | 327d | finish no earlier than 2006-06-15 | R2 | 3648h | 2918.4h | LCS3-UEPos-UTDOA |  | rlgross@trueposition.com | Rel-7 |  | TS25.305, TS25.453 | TSG | MCC_RAN |  |
| 78 | 14.5 | LCS Enhancements Related to Location-Based Services |  | 66d? | 2005-03-15 A | 2005-06-14 | 60% | 26.4d? | 2005-03-15 | 2005-06-15 | 66d? | 588d |  | R2 | 528h | 316.8h | LCS3-UEPos-Velocity |  | BRodilitz@SiRF.com | Rel-7 |  | 25.305, 25.331, 25.410, 25.413, 25.453 | TSG | MCC_RAN |  |
| 79 | 14.6 | Delete - RAN2 aspects for LBS | milestone | 0d? | 2005-06-15 A | 2005-06-15 A | 100% |  | 2005-03-15 | 2005-06-15 | 66d? |  | start no earlier than 2005-06-15 | R2 |  |  | LCS3-UEPos-LBS |  | BRodilitz@SiRF.com | Rel-7 |  | 25.305, 25.331, 25.410, 25.413, 25.453 | TSG | MCC_RAN | RP-31 |
| 80 | 14.7 | LCS Enhancements Related to Location-Based Services |  | 345d? | 2005-01-03 A | 2006-04-28 | 10% | 310.5d? | 2005-01-03 | 2006-04-07 | 330d? | 360d | finish no earlier than 2006-04-28 | GP | 2760h | 276h | LCS3-LBS |  | kjudge@sirf.com | Rel-7 |  | 43.059, 44.031, 48.008, 49.031 | TSG | Paolo |  |

Notes:
- 55: Text4: Alf Heidermark (Ericsson)
- 56: Text4: Mr Atle Monrad, Ericsson
- 57: Text4: Mr Atle Monrad, Ericsson
- 58: Text4: Mr Atle Monrad, Ericsson
- 59: Text4: Mr Atle Monrad, Ericsson
- 60: Text4: Mr Atle Monrad, Ericsson
- 61: Text4: Chris Pudney, Vodafone
- 64: NEW - inserted on 2/9/2004
- 69: Text4: Christophe Dubois (Axalto)
- 71: Approved SA#27. Appropriate place forEmergency work to be found / Text4: Ben Rodilitz, SiRF
- 72: CR approved in CT4#30
- 73: Text4: Mike Loushine, (Telcordia)
- 74: DAB - Should be SA1
- 75: Approved in SP#29 / Text4: Donghee Shim (LG Electronics Inc.); Patrice HÉDÉ (LG Electronics Mobilecomm France)
- 77: Text4: Robert Gross, TruePosition
- 78: Text4: Ben Rodilitz
- 79: Text4: Ben Rodilitz
- 80: Linked SP-040682 / Text4: Kevin Judge, SiRF Technologies

| ID | WBS | Task | Duration | Start | Finish | Complete | Remaining | Baseline start | Baseline finish | Baseline duration | Total slack | Constraint | Resources | Work | Actual work | Text1 | Text4 | Text5 | Text6 | Text7 | Text8 |
| --- | --- | --- | --- | --- | --- | --- | --- | --- | --- | --- | --- | --- | --- | --- | --- | --- | --- | --- | --- | --- | --- |
| 81 | 15 | **Advanced Global Navigation Satellite System (A-GNSS) concept** | 840d? | 2004-06-28 A | 2007-09-15 | 23% | 646.17d? | 2004-06-28 | 2006-04-14 | 470d? | 0d |  | S1 | 18097.6h | 2775.84h | LCS3-AGNSS | Michel MONNERAT | Michel.monnerat@space.alcatel.fr | Rel-7 | TSG | Michael |
| 82 | 15.1 | Support for GNSS in GERAN | 506.2d? | 2004-06-28 A | 2006-06-30 | 15% | 430.27d? | 2004-06-28 | 2006-04-14 | 451.2d? | 315d | finish no earlier than 2006-06-30 | GP | 4049.6h | 607.44h | AGNSS-GP | Richard Couty, ALCATEL SA | richard.couty@space.alcatel.fr | Rel-7 | TSG | Paolo |
| 83 | 15.2 | Global Navigation Satellite System (GNSS) in UTRAN | 457d? | 2005-12-15 A | 2007-09-15 | 10% | 411.3d? |  |  |  | 0d | finish no earlier than 2007-09-15 | R2 | 3656h | 365.6h | LCS3-GNSS-UTRAN | Alain Abinakhoul, France Telecom | alain.abinakhoul@francetelecom.com | Rel-7 |  | MCC_RAN |
| 84 | 15.3 | Towards A-GNSS Concept | 459d? | 2004-08-27 A | 2006-05-31 | 45% | 252.45d? | 2004-08-27 | 2005-09-29 | 285d? | 337d | finish no earlier than 2005-09-29 | S1 | 3672h | 1652.4h | GNSS | Richard Couty, ALCATEL SA | richard.couty@space.alcatel.fr | Rel-7 | TSG | Paolo |
| 85 | 16 | **Combinational Services** | 296d? | 2005-01-17 A | 2006-03-06 | 98% | 5.06d? | 2005-01-17 | 2005-12-07 | 233d? | 399d |  | S1 | 7544h | 7415.16h | CSICS | Robert Frank, TeliaSonera | Robert.Frank@teliasonera.com | Rel-7 | TSG | Michael |
| 86 | 16.1 | Stage 1 for CSICS | 104d? | 2005-01-17 A | 2005-06-09 A | 100% |  | 2005-01-17 | 2005-06-09 | 104d? |  | start no earlier than 2005-01-17 | S1 | 832h | 832h | CSICS |  |  | Rel-7 | TSG |  |
| 87 | 16.2 | Stage 2 for CSICS | 130d? | 2005-01-17 A | 2005-07-15 A | 100% |  | 2005-01-17 | 2005-07-15 | 130d? |  | start no earlier than 2005-01-17 | S2 | 1040h | 1040h | CSICS |  |  | Rel-7 |  |  |
| 88 | 16.3 | Stage 3 for CSICS CN aspects | 221d? | 2005-05-02 A | 2006-03-06 | 95% | 11.05d? | 2005-05-02 | 2005-10-28 | 130d? | 399d | finish no earlier than 2006-03-06 | C1 | 1768h | 1679.6h | CSICS | Peter Dawes (Vodafone) |  | Rel-7 | TSG | Andrijana |
| 89 | 16.4 | Stage 3 for codec aspects - check if really completed | 192d? | 2005-03-15 A | 2005-12-07 A | 100% |  | 2005-03-15 | 2005-12-07 | 192d? |  | finish no earlier than 2005-12-07 | S4 | 1536h | 1536h | CSICS-Codec | Per Fröjdh, Ericsson | Per.Frojdh@ericsson.com | Rel-7 | TSG | Paolo |
| 90 | 17 | Enhancement of E2E QoS | 336.4d? | 2004-06-28 A | 2005-12-01 A | 100% |  | 2004-06-28 | 2005-12-01 | 336.4d? |  | finish no earlier than 2005-12-01 | S2 | 2691.2h | 2691.2h | QoS7 |  |  | Rel-7 | TSG | Maurice |
| 91 | 18 | **System enhancements for fixed broadband access to IMS** | 823d? | 2003-11-05 A | 2006-12-29 | 44% | 464.35d? | 2004-08-03 | 2005-12-08 | 353d? | 185d |  | S2 | 33089.6h | 11217.8h | FBI |  |  | Rel-7 | TSG | Maurice |
| 92 | 18.1 | **TISPAN Rel 1 related aspects** | 611d? | 2003-11-05 A | 2006-03-08 | 65% | 214.43d? |  |  |  | 397d |  | S2 | 19856h | 9532.53h | FBI |  |  |  |  |  |
| 93 | 18.1.1 | Stage 2 of FBI for TISPAN R1 | 365d? | 2004-10-14 A | 2006-03-08 | 87% | 48d? |  |  |  | 397d | start no earlier than 2004-10-14 | S2 | 2920h | 2536h | FBI |  |  |  |  | Maurice |
| 94 | 18.1.2 | **Protocol impact of FBI for TISPAN R1** | 541d? | 2003-11-05 A | 2005-11-30 | 58% | 225.42d? | 2004-08-03 | 2005-11-30 | 347d? | 467d |  | C1 | 11104h | 6477.33h | FBI | Peter Leis (Siemens) |  | Rel-7 | TSG | Andrijana |
| 95 | 18.1.2.1 | CT1 aspects of FBI for TISPAN R1 | 347d? | 2004-08-03 A | 2005-11-30 | 85% | 52.05d? | 2004-08-03 | 2005-11-30 | 347d? | 467d | finish no earlier than 2005-03-03 | C1 | 2776h | 2359.6h | FBI | Siemens |  | Rel-7 | TSG | Andrijana |
| 96 | 18.1.2.2 | CT3 aspects of FBI for TISPAN R1 | 347d? | 2003-11-05 A | 2005-03-03 | 90% | 34.7d? | 2004-08-03 | 2005-11-30 | 347d? | 661d | finish no earlier than 2005-03-03 | C3 | 2776h | 2498.4h | FBI | Siemens |  | Rel-7 | TSG | Andrijana |
| 97 | 18.1.2.3 | CT4 aspects of FBI for TISPAN R1 | 347d? | 2003-11-05 | 2005-03-03 |  |  | 2004-08-03 | 2005-11-30 | 347d? | 661d | finish no earlier than 2005-03-03 | C4 | 2776h |  | FBI | Siemens |  | Rel-7 | TSG | Andrijana |
| 98 | 18.1.3 | Security Enhancements for FBI | 118d? | 2005-06-28 A | 2005-12-08 | 55% | 53.1d? | 2005-06-28 | 2005-12-08 | 118d? | 461d | start no earlier than 2005-06-28 | S3 | 944h | 519.2h | FBI-ISE | Bengt Sahlin, Ericsson | Bengt.Sahlin@ericsson.com | Rel-7 |  | Mike |
| 99 | 18.2 | **PacketCable Related aspects** | 228d? | 2006-02-01 A | 2006-12-15 | 4% | 218.23d? |  |  |  | 195d |  | S2 | 5576h | 168h | FBI-PCBL |  |  |  |  |  |
| 100 | 18.2.1 | Stage 2 of FBI for PacketCable | 152d? | 2006-02-01 A | 2006-08-31 | 14% | 131d? |  |  |  | 271d | start no earlier than 2006-02-01 | S2 | 1216h | 168h | FBI-PCBL |  |  |  |  |  |
| 101 | 18.2.2 | Protocol impact of FBI for PacketCable | 152d? | 2006-05-01 | 2006-11-28 |  |  |  |  |  | 208d | start no earlier than 2006-05-01 | C1 | 1216h |  | FBI-PCBL |  |  |  |  |  |
| 102 | 18.2.3 | SA5 Charging aspects of FBI for PacketCable | 186d? | 2006-03-31 | 2006-12-15 |  |  |  |  |  | 195d | finish no earlier than 2006-12-15 | S5 | 1488h |  | FBI-PCBL-CH | CableLabs | Bernie McKibben | Rel-7 |  | Adrian |
| 103 | 18.3 | **TISPAN Rel 2 related aspects** | 218d? | 2006-03-01 | 2006-12-29 |  |  |  |  |  | 185d |  | S2 | 4176h |  | FBI-TISP2 |  |  |  |  |  |
| 104 | 18.3.1 | Stage 2 of FBI for TISPAN R2 | 152d? | 2006-03-01 | 2006-09-28 |  |  |  |  |  | 251d | start no earlier than 2006-03-01 | S2 | 1216h |  | FBI-TISP2 |  |  |  |  |  |
| 105 | 18.3.2 | Protocol impact of FBI for TISPAN R2 | 152d? | 2006-06-01 | 2006-12-29 |  |  |  |  |  | 185d | start no earlier than 2006-06-01 | C1 | 1216h |  | FBI-TISP2 |  |  |  |  |  |
| 106 | 19 | Access Security Enhancements | 195d? | 2005-01-03 A | 2005-09-30 | 30% | 136.5d? | 2005-01-03 | 2005-09-30 | 195d? | 510d | finish no earlier than 2005-09-30 | S3 | 1560h | 468h | ACCSEC2 | Bengt Sahlin, Ericsson | Bengt.Sahlin@ericsson.com | Rel-7 | TSG | Michael |

Notes:
- 82: Started
- 83: Text3: TS 25.305,TS 25.331,TS 25.306,TS 25.413,TS 25.423,TS 25.433,TS 25.453,TS 25.171,TS 34.171
- 86: Text3: 22.279
- 87: Text3: 23.279
- 88: Text3: New TS 24.279, 24.229, 24.008
- 89: Started / Text3: TS 26.141, 26.235, 26.236
- 90: DAB - pushed back to June / Text3: 23.802
- 94: Text3: new TR 24.819, 24.229, 29.229, 29.163, 29.209
- 95: Text3: new TR 24.819, 24.229, 29.229, 29.163, 29.209
- 96: Text3: new TR, 29.229, 29.163
- 97: Text3: 29.209
- 98: Duplicated entry ("ACCSEC2", "Access Security Enhancements", SP-040865) deleted by A.Sultan / Text3: 33.102, 43.020
- 102: 03/2006 SA#31 WID approved / Text3: 32.240, 32.260, 32.298, 32.299
- 106: WID approved SA#26. Record created after SA#27. It is about improved GERAN security / Text3: 33.102, 43.020

| ID | WBS | Task | Type | Duration | Start | Finish | Complete | Remaining | Baseline start | Baseline finish | Baseline duration | Total slack | Constraint | Resources | Work | Actual work | Text1 | Text4 | Text6 | Text3 | Text5 | Text7 | Text8 |
| --- | --- | --- | --- | --- | --- | --- | --- | --- | --- | --- | --- | --- | --- | --- | --- | --- | --- | --- | --- | --- | --- | --- | --- |
| 107 | 20 | **Mp (MRFC - MRFP) interface** |  | 160d | 2006-02-13 A | 2006-09-22 | 23% | 124d | 2002-12-13 | 2005-06-01 | 644d | 255d |  | C4 | 3840h | 864h | Mp | Emmanuel Gay (Orange) | Rel-7 |  |  |  |  |
| 108 | 20.1 | CT1 aspects of Mp | milestone | 0d | 2006-02-13 | 2006-02-13 |  |  | 2002-12-13 | 2005-06-01 | 644d | 415d | finish no earlier than 2006-02-13 | C1 |  |  | Mp | Orange | Rel-7 | 24.229 |  |  |  |
| 109 | 20.2 | CT3 aspects of Mp |  | 160d | 2006-02-13 | 2006-09-22 |  |  | 2002-12-13 | 2005-06-01 | 644d | 255d | start no earlier than 2006-02-13 | C3 | 1280h |  | Mp | Orange | Rel-7 | 29.162 |  |  |  |
| 110 | 20.3 | CT4 aspects of Mp |  | 160d | 2006-02-13 A | 2006-09-22 | 45% | 88d | 2002-12-13 | 2005-06-01 | 644d | 255d | finish no earlier than 2006-09-22 | C4 | 1280h | 576h | Mp | Orange | Rel-7 | 29.333 |  |  |  |
| 111 | 21 | IMS Stage 3 IETF Protocol alignment |  | 461d? | 2004-12-10 A | 2006-09-15 | 40% | 276.6d? | 2004-12-10 | 2005-12-09 | 261d? | 260d | finish no earlier than 2006-09-15 | C1 | 3688h | 1475.2h | IMSProtoc |  | Rel-7 | TR 24.930 |  |  |  |
| 112 | 22 | **Support of SMS and MMS over generic 3GPP IP access** |  | 432d? | 2004-10-14 A | 2006-06-09 | 83% | 71.34d? | 2004-10-14 | 2006-06-09 | 432d? | 330d |  | S2 | 6944h | 4088.4h | SMSIP | Wenlin Zhang (Huawei) | Rel-7 | TR 23.abc, TS 23.abc | zhangwenlin@huawei.com | TSG | Maurice |
| 113 | 22.1 | FS on SMSIP |  | 173d? | 2004-10-14 A | 2005-06-13 A | 100% |  | 2004-10-14 | 2005-06-13 | 173d? |  | start no earlier than 2004-10-14 | S2 | 1384h | 1384h | SMSIP |  | Rel-7 | 23.804 |  |  |  |
| 114 | 22.2 | Stage 2 for SMSIP |  | 263d? | 2005-06-08 A | 2006-06-09 | 73% | 72d? | 2005-06-08 | 2006-06-09 | 263d? | 330d | start no earlier than 2005-06-08 | S2 | 2104h | 1528h | SMSIP |  | Rel-7 | 23.204 |  |  |  |
| 115 | 23 | **Evolution of Policy Control and Charging** |  | 567d? | 2004-10-14 A | 2006-12-15 | 35% | 367.32d? | 2004-10-14 | 2006-06-16 | 437d? | 195d |  | S2 | 17984h | 6333.45h | PCC |  | Rel-7 |  |  | TSG | Maurice |
| 116 | 23.1 | TR for PCC |  | 315d? | 2004-10-14 A | 2005-12-29 A | 100% |  | 2004-10-14 | 2005-12-29 | 315d? |  | finish no earlier than 2005-12-28 | S2 | 2520h | 2520h | PCC |  | Rel-7 |  |  |  |  |
| 117 | 23.2 | Stage 2 for PCC |  | 315d? | 2005-07-04 A | 2006-09-15 | 55% | 142d? | 2005-07-04 | 2006-06-16 | 250d? | 260d | finish no earlier than 2006-09-15 | S2 | 2520h | 1384h | PCC |  | Rel-7 | 23.203 |  |  |  |
| 118 | 23.3 | Evolution of policy control and flow based bearer level charging |  | 173d? | 2006-02-01 | 2006-09-29 |  |  | 2005-07-04 | 2006-06-16 | 250d? | 250d | start no earlier than 2006-02-01 | S2 | 1384h |  | PCC | Balazs Bertenyi (Nokia) | Rel-7 | 23.207, 23.125, 23.002, 23.228 | balazs.bertenyi@nokia.com |  |  |
| 119 | 23.4 | SA5 Charging aspects of PCC |  | 186d? | 2006-03-31 | 2006-12-15 |  |  |  |  |  | 195d | finish no earlier than 2006-12-15 | S5 | 1488h |  | PCC-CH | Nokia | Rel-7 | 32.250, 32.251, 32.298, 32.299 | ALEXANDER, Benni |  | Adrian |
| 120 | 23.5 | Gx reference point for Policy and Charging Control |  | 260d? | 2005-12-02 A | 2006-11-30 | 20% | 208d? |  |  |  | 206d | start no earlier than 2005-12-02 | C3 | 2080h | 416h | PCC | Thomas Belling (Siemens) | Rel-7 | 29.210, 29.207, 29.208 | thomas.belling@siemens.com |  | Seung Don |
| 121 | 23.6 | Rx reference point for PCC CT3 aspects |  | 260d? | 2005-12-02 A | 2006-11-30 | 20% | 208d? |  |  |  | 206d | start no earlier than 2005-12-02 | C3 | 2080h | 416h | PCC | Javier Pastor (Ericsson) | Rel-7 | 29.209, 29.211, 24.229 | j.javier.pastor@ericsson.com |  | Seung Don |
| 122 | 23.7 | Rx reference point for PCC CT1 aspects |  | 172d? | 2005-12-02 | 2006-09-29 |  |  |  |  |  | 250d | start no earlier than 2005-12-02 | C1 | 1376h |  | PCC |  | Rel-7 |  |  |  |  |
| 123 | 24 | Video Codec Performance Requirements |  | 453d? | 2005-01-03 A | 2006-09-27 | 50% | 226.5d? | 2005-01-03 | 2006-09-27 | 453d? | 252d | finish no earlier than 2006-09-27 | S4 | 3624h | 1812h | VICPer | Juergen Pandel (Siemens AG) | Rel-7 | 26.234, 26.235, 26.346, 26.140 | juergen.pandel@siemens.com | TSG | Paolo |
| 124 | 25 | delete at CT#32 - DIAMETER on the GGSN Gi interface |  | 531d? | 2004-09-10 | 2006-09-22 |  |  | 2004-09-10 | 2005-09-16 | 266d? | 255d | finish no earlier than 2006-09-22 | C3 | 4248h |  | DIAMGi |  | Rel-7 | 29.061 |  | TSG | Seung Don |
| 125 | 26 | delete at CT#32 - DIAMETER on the PDG Wi inteface |  | 531d? | 2004-09-10 | 2006-09-22 |  |  | 2004-09-10 | 2005-09-16 | 266d? | 255d | finish no earlier than 2006-09-22 | C3 | 4248h |  | DIAMWi |  | Rel-7 | 29.161 |  | TSG | Seung Don |
| 126 | 27 | Bandwidth Saving at Nb Interface with IP transport |  | 126d? | 2006-03-10 | 2006-09-01 |  |  |  |  |  | 270d | finish no earlier than 2006-09-01 | C3 | 1008h |  | BSNbIP | Thomas BELLING(Siemens) | Rel-7 | 29.414, 29.415 | thomas.belling@siemens.com |  | Seung Don |
| 127 | 28 | **CAMEL Trunk Triggers** |  | 251d? | 2004-12-17 A | 2005-12-05 A | 100% |  | 2004-12-17 | 2005-12-05 | 251d? |  |  | S1 | 6024h | 6024h | TTCAMEL | Amar Deol, Nortel Networks | Rel-7 |  | deola@nortelnetworks.com | TSG | Michael |
| 128 | 28.1 | Stage 1 for CAMEL Trunk Triggers |  | 251d? | 2004-12-17 A | 2005-12-05 A | 100% |  | 2004-12-17 | 2005-12-05 | 251d? |  |  | S1 | 2008h | 2008h | TTCAMEL | Amar Deol, Nortel Networks | Rel-7 |  | deola@nortelnetworks.com | TSG | Michael |
| 129 | 28.2 | CAMEL Trunk Originated Trigger Detection Points |  | 251d? | 2004-12-17 A | 2005-12-05 A | 100% |  | 2004-12-17 | 2005-12-05 | 251d? |  | start no earlier than 2004-12-17 | C4 | 2008h | 2008h | CamelR7 | David Hutton, Nortel Networks | Rel-7 |  | dhutton@nortel.com | TSG | Kimmo |
| 130 | 29 | MS Antenna Performance Evaluation Method and Requirements |  | 326d? | 2005-01-28 A | 2006-04-28 | 55% | 146.7d? | 2005-01-28 | 2005-11-11 | 206d? | 360d | finish no earlier than 2006-04-28 | G1 | 2608h | 1434.4h | APEMR | Ulf.Tegth (TeliaSonera) | Rel-7 | 25.9xx, 45.005 | Ulf.Tegth@teliasonera.com | TSG | Paolo |

Notes:
- 110: indication in CT4#30 45%
- 111: TR 24.930: Signalling flows for the session setup in the IM CN subsystem based on Session Initiation Protocol (SIP)
- 112: Revised at SP#29
- 118: Approved at SP#29. 23.125 will be discontinued from Release 7.
- 119: 03/2006 SA#31 WID approved
- 120: Approved at CP#30, Revised at CP#31
- 121: Approved at CP#30, Revised at CP#31
- 124: 13/12/2005 08:00
- 125: 13/12/2005 08:00
- 126: Approved at CP#31
- 129: Not started
- 130: Started

| ID | WBS | Task | Type | Duration | Start | Finish | Complete | Remaining | Baseline start | Baseline finish | Baseline duration | Total slack | Constraint | Resources | Work | Actual work | Text1 | Text4 | Text5 | Text6 | Text7 | Text8 |
| --- | --- | --- | --- | --- | --- | --- | --- | --- | --- | --- | --- | --- | --- | --- | --- | --- | --- | --- | --- | --- | --- | --- |
| 131 | 30 | **Lower 700 MHz Inclusion in the GERAN Specifications** |  | 345d? | 2005-01-03 A | 2006-04-28 | 42% | 200.89d? | 2005-01-03 | 2006-04-28 | 345d? | 360d |  | GP | 6552h | 2177.6h | GSM710 | Dave Cotton (UTC) | dcotton@mtview.union-tel.com | Rel-7 | TSG | Paolo |
| 132 | 30.1 | Inclusion of the 698 – 746 MHz band into GERAN core specifications |  | 129d? | 2005-01-03 A | 2005-06-30 A | 100% |  | 2005-01-03 | 2005-06-30 | 129d? |  | finish no earlier than 2005-06-30 | G1 | 1032h | 1032h | GSM710-core |  |  | Rel-7 |  | Paolo |
| 133 | 30.2 | G1 aspects of Inclusion of the 698 – 746 MHz band into GERAN test specifications |  | 172.5d? | 2005-08-31 A | 2006-04-28 | 20% | 138d? | 2005-08-31 | 2006-04-28 | 172.5d? | 360d | start no earlier than 2005-08-31 | G1 | 1380h | 276h | GSM-710-test |  |  | Rel-7 |  | Stoyan |
| 134 | 30.3 | G3 aspects of Inclusion of the 698 – 746 MHz band into GERAN test specifications |  | 172.5d? | 2005-08-31 A | 2006-04-28 | 20% | 138d? |  |  |  | 360d | finish no earlier than 2006-04-28 | G3 | 1380h | 276h | GSM-710-test |  |  | Rel-7 |  | Stoyan |
| 135 | 31 | **Enhancements of VGCS for public authority officials** |  | 536d? | 2004-08-27 A | 2006-09-15 | 86% | 76.25d? | 2004-08-27 | 2005-12-06 | 333d? | 260d |  | S1 | 19560h | 13414.2h | EVGCS | Siemens |  | Rel-7 | TSG | Andrijana |
| 136 | 31.1 | Stage 1 | milestone | 0d? | 2004-08-27 A | 2004-08-27 A | 100% |  | 2004-08-27 | 2004-08-27 | 0d? |  | finish no earlier than 2004-08-27 | S1 |  |  | EVGCS | Joerg Swetina (Siemens AG) | joerg.swetina@SIEMENS.COM | Rel-7 | TSG | Michael |
| 137 | 31.2 | **Architecture and protocol aspects** |  | 536d? | 2004-08-27 A | 2006-09-15 | 93% | 36.91d? | 2004-08-27 | 2005-12-06 | 333d? | 260d |  | C1 | 11784h | 10972.6h | EVGCS | Robert Zaus (Siemens) |  | Rel-7 |  |  |
| 138 | 31.2.1 | CT1 aspects of EVGCS |  | 536d? | 2004-08-27 A | 2006-09-15 | 93% | 37.52d? | 2004-08-27 | 2005-12-06 | 333d? | 260d | finish no earlier than 2006-09-15 | C1 | 4288h | 3987.84h | EVGCS | Siemens |  | Rel-7 |  |  |
| 139 | 31.2.2 | CT4 aspects of EVGCS |  | 401d? | 2004-08-27 A | 2006-03-10 | 93% | 27d? | 2004-08-27 | 2005-12-06 | 333d? | 395d | finish no earlier than 2006-03-10 | C4 | 3208h | 2992h | EVGCS | Siemens |  | Rel-7 |  |  |
| 140 | 31.3 | GERAN2 aspects |  | 436d? | 2004-08-27 A | 2006-04-28 | 70% | 130.8d? | 2004-08-27 | 2005-11-11 | 316d? | 360d | finish no earlier than 2006-04-28 | G2 | 3488h | 2441.6h | EVGCS | Ken Isaacs (Siemens) | kenneth.isaacs@roke.co.uk | Rel-7 | TSG | Gert |
| 141 | 32 | **Improvements of VGCS for parallel use of services** |  | 381d? | 2005-03-15 A | 2006-08-29 | 33% | 254.21d? | 2005-03-15 | 2005-12-09 | 194d? | 273d |  | S1 | 8830.16h | 1936h | IVGCS |  |  | Rel-7 |  |  |
| 142 | 32.1 | Service Requirements for VGCS improvements |  | 62d? | 2005-03-15 A | 2005-06-08 A | 100% |  | 2005-03-15 | 2005-06-08 | 62d? |  | finish no earlier than 2005-06-08 | S1 | 496h | 496h | IVGCS | Kurt Bischinger (T-Mobile) | kurt.bischinger@t-mobile.at | Rel-7 | TSG | Michael |
| 143 | 32.2 | Stage 2 modifications for VGCS improvements |  | 142d? | 2005-12-01 A | 2006-06-16 | 32% | 97d? | 2005-03-15 | 2005-09-28 | 142d? | 325d | start no earlier than 2005-12-01 | C1 | 1136h | 360h | IVGCS | Kurt Bischinger (T-Mobile) | kurt.bischinger@t-mobile.at | Rel-7 | TSG |  |
| 144 | 32.3 | **Architecture and protocol aspects** |  | 194d? | 2005-12-01 A | 2006-08-29 | 23% | 149d? | 2005-03-15 | 2005-12-09 | 194d? | 273d |  | C1 | 4656h | 1080h | IVGCS | Dieter Jacobsohn (T-Mobile) |  | Rel-7 |  |  |
| 145 | 32.3.1 | CT1 aspects of IVGCS |  | 194d? | 2005-12-01 A | 2006-08-29 | 23% | 149d? | 2005-03-15 | 2005-12-09 | 194d? | 273d | start no earlier than 2005-12-01 | C1 | 1552h | 360h | IVGCS | T-Mobile |  | Rel-7 |  |  |
| 146 | 32.3.2 | CT4 aspects of IVGCS |  | 194d? | 2005-12-01 A | 2006-08-29 | 23% | 149d? | 2005-03-15 | 2005-12-09 | 194d? | 273d | start no earlier than 2005-12-01 | C4 | 1552h | 360h | IVGCS | T-mobile |  | Rel-7 |  |  |
| 147 | 33 | **OSA Rel-7** |  | 449d? | 2005-03-15 A | 2006-12-01 | 12% | 397.11d? | 2005-03-15 | 2005-09-28 | 142d? | 205d |  | S1 | 11576h | 1291.09h | OSA7 | Eamonn Murray (AePONA) | eamonn.murray@aepona.com | Rel-7 | TSG | Michael |
| 148 | 33.1 | Service Requirements for OSA Service Broker |  | 62d? | 2005-03-15 A | 2005-06-08 A | 100% |  | 2005-03-15 | 2005-06-08 | 62d? |  | finish no earlier than 2005-06-08 | S1 | 496h | 496h | OSA7-SB | Eamonn Murray (AePONA) | eamonn.murray@aepona.com | Rel-7 | TSG | Michael |
| 149 | 33.2 | Stage 2 OSA API Service Brokering |  | 156d? | 2006-04-28 A | 2006-12-01 | 13% | 136.3d? | 2005-03-15 | 2005-09-28 | 142d? | 205d |  | C5 | 1248h | 157.6h | OSA7-SB | Eamonn Murray (AePONA) | eamonn.murray@aepona.com | Rel-7 | TSG | Adrian |
| 150 | 33.3 | Stage 3 OSA API Service Brokering |  | 156d? | 2006-04-28 A | 2006-12-01 | 10% | 140.4d? |  |  |  | 205d | finish no earlier than 2006-12-01 | C5 | 1248h | 124.8h | OSA7-SB | Damian O’Neill (AePONA) |  | Rel-7 |  |  |
| 151 | 33.4 | **OSA Stage 2/3 enhancements** |  | 156d? | 2006-04-28 A | 2006-12-01 |  | 156d? |  |  |  | 205d |  | C5 | 4992h | 97.6h | OSA7 | Damian O’Neill (AePONA) | damian.oneill@aepona.com | Rel-7 |  | Adrian |
| 152 | 33.4.1 | Parlay X Message Broadcast |  | 156d? | 2006-04-28 | 2006-12-01 |  |  |  |  |  | 205d | finish no earlier than 2006-12-01 | C5 | 1248h |  | OSA7 | Mr. JeongHwan Kim (ETRI) |  | Rel-7 |  |  |
| 153 | 33.4.2 | Parlay X Geocoding and Mapping |  | 156d? | 2006-04-28 | 2006-12-01 |  |  |  |  |  | 205d | finish no earlier than 2006-12-01 | C5 | 1248h |  | OSA7 | Mrs. Hyunkyung Yoo (ETRI) |  | Rel-7 |  |  |
| 154 | 33.4.3 | Parlay X Application driven QoS |  | 156d? | 2006-04-28 | 2006-12-01 |  |  |  |  |  | 205d | finish no earlier than 2006-12-01 | C5 | 1248h |  | OSA7 | Mr. Darren Gunning |  | Rel-7 |  |  |
| 155 | 34 | Dynamic and interactive multimedia scenes |  | 452d? | 2005-03-15 A | 2006-12-06 | 35% | 293.8d? | 2005-03-15 | 2006-09-27 | 402d? | 202d | finish no earlier than 2006-12-06 | S4 | 3616h | 1265.6h | DIMS | Gaëlle MARTIN-COCHER (Streamezzo) | gaelle.martin-cocher@streamezzo.com | Rel-7 | TSG | Paolo |
| 156 | 35 | Liberty Alliance and 3GPP Security Interworking |  | 147d? | 2005-03-10 A | 2005-09-30 | 80% | 29.4d? | 2005-03-10 | 2005-09-30 | 147d? | 510d | finish no earlier than 2005-09-30 | S3 | 1176h | 940.8h | LibSec | Silke Holtmanns, Nokia | Silke.Holtmanns@NOKIA.COM | Rel-7 | TSG | Maurice |

Notes:
- 131: Started / Text3: 24.008, 43.022, 44.018, 44.118, 45, 001, 45.005, 51.010, 51.021
- 132: Completed / Text3: 24.008, 43.022, 44.018, 44.118, 45, 001, 45.005,
- 133: Started / Text3: 51.021
- 134: Started / Text3: 51.010
- 135: Text3: 43.068, 44.068, 24.008, 29.002
- 136: Text3: 42.068, 43.068
- 137: Text3: 43.068, 44.068
- 138: Text3: 43.068, 44.068, 24.008
- 139: Text3: 29.002
- 142: "completeed" as from Chris S' e-mail / Text3: 42.068
- 143: Text3: 43.068
- 144: Text3: 44.068
- 145: Text3: 43.068, 44.068, 24.008
- 146: Text3: 29.002
- 148: az: WID URL corrected / Text3: 22.127
- 149: Text3: 23.198
- 150: Text3: 29.198-16
- 151: CT#30: WID approved. / Text3: 23.198, 29.198,29.998,29.199
- 152: Text3: 29.199-15
- 153: Text3: 29.199-16
- 154: Text3: 29.199-17
- 155: Text3: 26.234, 23.346, 26.140, 26.244
- 156: WID approved SA#27. / Text3: 33.980

| ID | WBS | Task | Type | Duration | Start | Finish | Complete | Remaining | Baseline start | Baseline finish | Baseline duration | Total slack | Constraint | Resources | Work | Actual work | Text4 | Text5 | Text6 | Text7 | Text8 | Text1 | Text10 |
| --- | --- | --- | --- | --- | --- | --- | --- | --- | --- | --- | --- | --- | --- | --- | --- | --- | --- | --- | --- | --- | --- | --- | --- |
| 157 | 36 | **WLAN-UMTS Interworking Phase 2** |  | 371d? | 2004-01-05 A | 2005-06-07 | 99% | 0d? | 2004-01-05 | 2005-06-07 | 371d? | 594d |  | S1 | 3888h | 3888h | Fredric Paint, Telenor | frederic.paint@telenor.com | Rel-7 | TSG | Michael |  |  |
| 158 | 36.1 | Stage 1 on Session Continuity |  | 115d? | 2004-01-05 A | 2004-06-11 A | 100% |  | 2004-01-05 | 2004-06-11 | 115d? |  | start no earlier than 2004-01-05 | S1 | 920h | 920h |  |  | Rel-7 |  |  | WLAN-SC | SP-24 |
| 159 | 36.2 | Stage 2 on Session Continuity: covered by SAE | milestone | 0d? | 2005-06-07 | 2005-06-07 |  |  | 2005-06-07 | 2005-06-07 | 0d? | 594d | finish no earlier than 2005-06-07 | S2 |  |  |  |  | Rel-7 |  |  |  |  |
| 160 | 37 | **WLAN Interworking – Private Network access from WLAN 3GPP IP Access** |  | 252d? | 2005-10-10 A | 2006-09-26 | 15% | 213.42d? | 2005-10-10 | 2006-10-20 | 270d? | 253d |  | S2 | 6920h | 860.27h |  |  | Rel-7 |  | Maurice | WLANPNA |  |
| 161 | 37.1 | WLAN-PNA - Stage 2 |  | 185d? | 2005-10-10 A | 2006-06-23 | 56% | 82d? |  |  |  | 320d | start no earlier than 2005-10-10 | S2 | 1480h | 824h | Toshiyuki Tamura (NEC) | tamurato@aj.jp.nec.com | Rel-7 |  | Maurice | WLANPNA-st2 |  |
| 162 | 37.2 | **WLAN-PNA - Stage 3** |  | 170d? | 2006-02-01 A | 2006-09-26 | 1% | 168.87d? | 2005-10-10 | 2006-10-20 | 206.31d? | 253d |  | C1 | 5440h | 36.27h | Pierre-Jean Muller (NEC) | pierre-jean.muller@nectech.fr | Rel-7 | TSG | Andrijana | WLANPNA-St3 |  |
| 163 | 37.2.1 | CT1 aspets for WLAN-PNA |  | 170d? | 2006-02-01 A | 2006-09-26 | 2% | 166.6d? |  |  |  | 253d | start no earlier than 2006-02-01 | C1 | 1360h | 27.2h | Pierre-Jean Muller (NEC) | pierre-jean.muller@nectech.fr | Rel-7 |  | Andrijana | WLANPNA-st3-CT1 |  |
| 164 | 37.2.2 | CT3 aspets for WLAN-PNA |  | 170d? | 2006-02-01 | 2006-09-26 |  |  |  |  |  | 253d | start no earlier than 2006-02-01 | C3 | 1360h |  | Pierre-Jean Muller (NEC) | pierre-jean.muller@nectech.fr | Rel-7 |  | Andrijana | WLANPNA-st3-CT3 |  |
| 165 | 37.2.3 | CT4 aspets for WLAN-PNA |  | 170d? | 2006-02-01 | 2006-09-26 |  |  |  |  |  | 253d | start no earlier than 2006-02-01 | C4 | 1360h |  | Pierre-Jean Muller (NEC) | pierre-jean.muller@nectech.fr | Rel-7 |  | Andrijana | WLANPNA-st3-CT4 |  |
| 166 | 38 | **Enhancements to support QoS provisioning over 3GPP/WLAN Interworking** |  | 340d? | 2005-03-14 A | 2006-06-30 | 68% | 108d? | 2005-03-14 | 2006-09-11 | 391d? | 315d |  | S2 | 5440h | 3712h | Osok Song, Samsung | osok.song@samsung.com | Rel-7 |  | Maurice | WLAN-QOS |  |
| 167 | 38.1 | TR on support of QoS on WLAN |  | 232d? | 2005-03-14 A | 2006-01-31 A | 100% |  |  |  |  |  | start no earlier than 2005-03-14 | S2 | 1856h | 1856h |  |  | Rel-7 |  |  |  |  |
| 168 | 38.2 | Stage 2 on support of QoS over 3GPP/WLAN interworking |  | 108d? | 2006-02-01 | 2006-06-30 |  |  |  |  |  | 315d | start no earlier than 2006-02-01 | S2 | 864h |  |  |  | Rel-7 |  |  |  |  |
| 169 | 39 | **Voice call continuity between CS and IMS (incl. I-WLAN)** |  | 511d? | 2004-12-31 A | 2006-12-15 | 31% | 351.25d? | 2004-12-31 | 2006-06-23 | 386d? | 195d |  | S2 | 17120h | 4354.4h | Andy Bennett, Lucent; Roger Bunting, Cingular | andybennett@lucent.com | Rel-7 |  | Maurice | VCC |  |
| 170 | 39.1 | TR for VCC |  | 245d? | 2004-12-31 A | 2005-12-08 A | 100% |  | 2004-12-31 | 2005-12-08 | 245d? |  | finish no earlier than 2005-12-08 | S2 | 1960h | 1960h |  |  | Rel-7 |  |  | VCC |  |
| 171 | 39.2 | Stage 1 for VCC |  | 140d? | 2005-03-17 A | 2005-09-28 A | 100% |  | 2005-03-17 | 2005-09-28 | 140d? |  | finish no earlier than 2005-09-28 | S1 | 1120h | 1120h |  |  | Rel-7 |  | Mike | VCC |  |
| 172 | 39.3 | Stage 2 for VCC |  | 264d? | 2005-09-06 A | 2006-09-08 | 24% | 201d? | 2005-09-06 | 2006-06-09 | 199d? | 265d | finish no earlier than 2006-09-08 | S2 | 2112h | 504h |  |  | Rel-7 |  |  | VCC |  |
| 173 | 39.4 | **Stage 3 for VCC** |  | 196d? | 2006-02-01 | 2006-11-01 |  |  | 2005-09-23 | 2006-06-23 | 196d? | 227d |  | C1 | 6272h |  |  |  | Rel-7 |  |  | VCC |  |
| 174 | 39.4.1 | CT1 aspects of VCC |  | 196d? | 2006-02-01 | 2006-11-01 |  |  | 2005-09-23 | 2006-06-23 | 196d? | 227d | start no earlier than 2006-02-01 | C1 | 1568h |  | Lucent |  | Rel-7 |  |  | VCC |  |
| 175 | 39.4.2 | CT3 aspects of VCC |  | 196d? | 2006-02-01 | 2006-11-01 |  |  | 2005-09-23 | 2006-06-23 | 196d? | 227d | start no earlier than 2006-02-01 | C3 | 1568h |  | Lucent |  | Rel-7 |  |  | VCC |  |
| 176 | 39.4.3 | CT4 aspects of VCC |  | 196d? | 2006-02-01 | 2006-11-01 |  |  | 2005-09-23 | 2006-06-23 | 196d? | 227d | start no earlier than 2006-02-01 | C4 | 1568h |  | Lucent |  | Rel-7 |  |  | VCC |  |
| 177 | 39.5 | SA5 Charging aspects of VCC |  | 196d? | 2006-03-17 | 2006-12-15 |  |  |  |  |  | 195d | finish no earlier than 2006-12-15 | S5 | 1568h |  | Telefonica | Ms. Seguro, Blanca | Rel-7 |  | Adrian | VCC-CH |  |
| 178 | 40 | **OAM&P** |  | 740d? | 2004-02-16 A | 2006-12-15 | 27% | 542.66d? | 2004-02-16 | 2007-03-30 | 815d? | 195d |  | S5 | 76617.1h | 20270.6h | Christian TOCHE | toche@nortel.com | Rel-7 | TSG | Adrian | OAM7 |  |
| 179 | 40.1 | **Network Infrastructure Management** |  | 336d? | 2005-09-02 A | 2006-12-15 | 27% | 246.83d? | 2005-09-02 | 2006-12-22 | 341d? | 195d |  | S5 | 29160h | 7025.6h |  |  | Rel-7 |  |  | OAM7-NIM |  |
| 180 | 40.1.1 | Enhance NRM to accommodate NGN (IMS as basis of the Next Generation Network) |  | 336d? | 2005-09-02 A | 2006-12-15 | 20% | 268.8d? | 2005-09-02 | 2006-12-22 | 341d? | 195d | finish no earlier than 2006-12-15 | S5 | 2688h | 537.6h | BT |  | Rel-7 |  |  | OAM7-NIM-NGN |  |
| 181 | 40.1.2 | Network Management (NM) Itf-N performance criteria |  | 336d? | 2005-09-02 A | 2006-12-15 | 30% | 235.2d? | 2005-09-02 | 2005-12-07 | 69d? | 195d | finish no earlier than 2006-12-15 | S5 | 2688h | 806.4h | China Mobile |  | Rel-7 |  |  | OAM7-NIM |  |
| 182 | 40.1.3 | Subscription Management (SuM) IRP Solution Sets |  | 336d? | 2005-09-02 A | 2006-12-15 | 55% | 151.2d? | 2005-09-02 | 2006-03-31 | 151d? | 195d | finish no earlier than 2006-12-15 | S5 | 2688h | 1478.4h | Ericsson |  | Rel-7 |  |  | OAM7-NIM-SuM |  |
| 183 | 40.1.4 | Integration Reference Point (IRP) Security Management |  | 336d? | 2005-09-02 A | 2006-12-15 | 40% | 201.6d? | 2005-09-02 | 2006-06-30 | 216d? | 195d | finish no earlier than 2006-12-15 | S5 | 2688h | 1075.2h | Huawei |  | Rel-7 |  |  | OAM7-NIM |  |
| 184 | 40.1.5 | Integration Reference Point (IRP) Methodology |  | 336d? | 2005-09-02 A | 2006-12-15 | 15% | 285.6d? | 2005-09-02 | 2006-12-07 | 330d? | 195d | finish no earlier than 2006-12-15 | S5 | 2688h | 403.2h | Ericsson |  | Rel-7 |  |  | OAM7-NIM |  |
| 185 | 40.1.6 | Management of Legacy Equipment |  | 336d? | 2005-09-02 A | 2006-12-15 | 20% | 268.8d? | 2005-09-02 | 2005-12-07 | 69d? | 195d | finish no earlier than 2006-12-15 | S5 | 2688h | 537.6h | Siemens |  | Rel-7 |  |  | OAM7-NIM |  |
| 186 | 40.1.7 | Rules for Vendor Specific Extensions |  | 336d? | 2005-09-02 A | 2006-12-15 | 20% | 268.8d? | 2005-09-02 | 2006-03-31 | 151d? | 195d | finish no earlier than 2006-12-15 | S5 | 2688h | 537.6h | Siemens |  | Rel-7 |  |  | OAM7-NIM |  |
| 187 | 40.1.8 | CN CS Bearer Transport Network (BTN) relative NRM |  | 336d? | 2005-09-02 A | 2006-12-15 | 45% | 184.8d? | 2005-09-02 | 2005-12-07 | 69d? | 195d | finish no earlier than 2006-12-15 | S5 | 2688h | 1209.6h | China Mobile |  | Rel-7 |  |  | OAM7-NIM |  |
| 188 | 40.1.9 | Repeater Network Resource Model (NRM) definition |  | 220d? | 2006-02-13 A | 2006-12-15 | 5% | 209d? |  |  |  | 195d | start no earlier than 2006-02-13 | S5 | 1760h | 88h | China Mobile |  | Rel-7 |  |  | OAM7-NIM |  |
| 189 | 40.1.10 | UTRAN radio channel power monitoring |  | 220d? | 2006-02-13 A | 2006-12-15 | 20% | 176d? |  |  |  | 195d | start no earlier than 2006-02-13 | S5 | 1760h | 352h | China Mobile |  | Rel-7 |  |  | OAM7-NIM |  |
| 190 | 40.1.11 | Study on SA5 MTOSI XML Harmonization |  | 181d? | 2006-04-07 | 2006-12-15 |  |  |  |  |  | 195d | finish no earlier than 2006-12-15 | S5 | 1448h |  | Nortel |  | Rel-7 |  |  | OAM7-NIM-XML |  |

Notes:
- 157: Created at TSG#27 by A. Sultan because of WLAN items belonging to Rel-7
- 160: Placeholder created to Hold SA2 and CT1 BBs
- 161: Approved at SP#29 / Text3: 23.234, 33.234
- 162: Approved at CP#29
- 163: Approved at CP#29 / Text3: 24.234
- 164: Approved at CP#29 / Text3: 29.161
- 165: Approved at CP#29 / Text3: 29.234
- 166: Moved from FS section Feb 06 / Text3: 23.836
- 169: WID approved SA#27. Revised at SA#28. / Text3: 22.101, 22.228, 23.228
- 170: Text3: 23.806
- 172: Text3: 23.206
- 173: Text3: new TS, 24.229, 23.008, 23.009, 23.078, 29.078, 29.163, 29.228, 29.229, 29.230, 29.278, 29.328, 29.329
- 174: Text3: new TS, 24.229
- 175: Text3: 29.163
- 176: Text3: 23.008, 23.009, 23.078, 29.078, 29.228, 29.229, 29.230, 29.278, 29.328, 29.329
- 177: 03/2006 SA#31 WID approved / Text3: 32.250, 32.252, 32.260, 32.298, 32.299
- 180: Text3: 32.632, 32.633, 32.634, 32.635
- 181: Text3: new TS 32.yzx
- 182: Text3: 32.101,32.175, new TSs 32.161,32.307,32.317,32.607,32.617,32.667
- 183: Text3: New TSs 32.372,32.373,32.374; 32.111,32.30x,32.32x,32.33x,32.34x,32.35x,32.36x,32.41x,32.60x,32.61x,32.66x
- 184: Text3: New TSs 32.15w,32.15x,32.15y,32.15z; 32.150,32.151,32.152
- 185: Text3: new TS 32.xxx, New TSs 32.62n,32.63n,32.64n,32.65n,32.71n,32.74n,32.69n; For n = 1 to 5
- 186: Text3: 32.62n; For n = 1 to 5
- 187: Text3: New TSs 32.xx1,32.xx2, 32.xx3, 32.xx4
- 188: Text3: 32.64n; For n = 1 to 5
- 189: Text3: 32.403, 32.64n; For n = 1 to 5
- 190: Text3: new TR 32.8xy

| ID | WBS | Task | Duration | Start | Finish | Complete | Remaining | Baseline start | Baseline finish | Baseline duration | Total slack | Constraint | Resources | Work | Actual work | Text1 | Text6 | Text4 | Text7 | Text12 | Text5 | Text8 |
| --- | --- | --- | --- | --- | --- | --- | --- | --- | --- | --- | --- | --- | --- | --- | --- | --- | --- | --- | --- | --- | --- | --- |
| 191 | 40.2 | **Performance Management** | 336d? | 2005-09-02 A | 2006-12-15 | 33% | 225.79d? | 2005-09-02 | 2006-12-29 | 346d? | 195d |  | S5 | 20576h | 5867.2h | OAM7-PM | Rel-7 |  |  |  |  |  |
| 192 | 40.2.1 | Performance measurements definition for CN CS | 336d? | 2005-09-02 A | 2006-12-15 | 65% | 117.6d? | 2005-09-02 | 2006-03-31 | 151d? | 195d | finish no earlier than 2006-12-15 | S5 | 2688h | 1747.2h | OAM7-PM | Rel-7 | China Mobile |  |  |  |  |
| 193 | 40.2.2 | Enhancement UTRAN performance measurements definition | 336d? | 2005-09-02 A | 2006-12-15 | 20% | 268.8d? | 2005-09-02 | 2005-12-07 | 69d? | 195d | finish no earlier than 2006-12-15 | S5 | 2688h | 537.6h | OAM7-PM | Rel-7 | China Mobile |  |  |  |  |
| 194 | 40.2.3 | Add TDD specific counters in Performance measurement | 336d? | 2005-09-02 A | 2006-12-15 | 75% | 84d? | 2005-09-02 | 2006-12-29 | 346d? | 195d | finish no earlier than 2006-12-15 | S5 | 2688h | 2016h | OAM7-PM | Rel-7 | CATT |  |  |  |  |
| 195 | 40.2.4 | ATM bearer network Performance measurements | 336d? | 2005-09-02 A | 2006-12-15 | 30% | 235.2d? | 2005-09-02 | 2005-12-07 | 69d? | 195d | finish no earlier than 2006-12-15 | S5 | 2688h | 806.4h | OAM7-PM | Rel-7 | ZTE |  |  |  |  |
| 196 | 40.2.5 | IP bearer network Performance measurement definitions | 336d? | 2005-09-02 A | 2006-12-15 | 20% | 268.8d? | 2005-09-02 | 2005-12-07 | 69d? | 195d | finish no earlier than 2006-12-15 | S5 | 2688h | 537.6h | OAM7-PM | Rel-7 | China Mobile |  |  |  |  |
| 197 | 40.2.6 | Performance measurements definition for IMS | 336d? | 2005-09-02 A | 2006-12-15 | 5% | 319.2d? | 2005-09-02 | 2006-12-22 | 341d? | 195d | finish no earlier than 2006-12-15 | S5 | 2688h | 134.4h | OAM7-PM-IMS | Rel-7 | China Mobile |  |  |  |  |
| 198 | 40.2.7 | HSDPA performance measurements | 220d? | 2006-02-13 A | 2006-12-15 | 5% | 209d? |  |  |  | 195d | start no earlier than 2006-02-13 | S5 | 1760h | 88h | OAM7-PM | Rel-7 | China Mobile |  |  |  |  |
| 199 | 44.5 | **Trace Management** | 740d? | 2004-02-16 A | 2006-12-15 | 20% | 590.27d? | 2004-02-16 | 2007-03-30 | 815d? | 195d |  | S5 | 20961.1h | 3585.84h | OAM7-Trace | Rel-7 |  | TSG |  |  |  |
| 200 | 40.3.1 | DELETE Trace Management for IMS (merged with 35062) | 420d? | 2005-05-09 | 2006-12-15 |  |  | 2005-05-09 | 2005-12-08 | 154d? | 195d | finish no earlier than 2006-12-15 | S5 | 3360h |  | OAM7-Trace-IMS | Rel-7 | Nortel | TSG | SP-31 |  |  |
| 201 | 40.3.2 | SIP enhancements for trace | 603.14d? | 2004-02-16 A | 2006-06-16 | 2% | 591.08d? | 2004-02-16 | 2006-06-16 | 603.14d? | 325d | finish no earlier than 2006-06-16 | C1 | 4825.12h | 96.5h | OAM7-Trace-SIP | Rel-7 |  |  |  |  |  |
| 202 | 40.3.3 | End-to-end Service Level tracing for IMS | 286d? | 2005-11-11 A | 2006-12-15 | 20% | 228.8d? | 2005-11-11 | 2006-06-30 | 166d? | 195d | finish no earlier than 2006-12-15 | S5 | 2288h | 457.6h | OAM7-Trace-IMS | Rel-7 | Vodafone | TSG |  |  |  |
| 203 | 40.3.4 | IRP for Subscriber and Equipment Trace Management | 336d? | 2005-09-02 A | 2006-12-15 | 10% | 302.4d? | 2005-09-02 | 2007-03-30 | 411d? | 195d | finish no earlier than 2006-12-15 | S5 | 2688h | 268.8h | OAM7-Trace-IRP | Rel-7 | Nokia | TSG |  |  |  |
| 204 | 40.3.5 | Trace record content for UTRAN TDD | 420d? | 2005-05-09 A | 2006-12-15 | 75% | 105d? | 2005-05-09 | 2005-12-08 | 154d? | 195d | finish no earlier than 2006-12-15 | S5 | 3360h | 2520h | OAM7-Trace-TDD | Rel-7 | CATT | TSG |  |  |  |
| 205 | 41 | Trust Requirements for Open Platforms in 3GPP | 115d? | 2005-01-03 A | 2005-06-10 | 40% | 69d? | 2005-01-03 | 2005-06-10 | 115d? | 590d | finish no earlier than 2005-06-10 | S3 | 920h | 368h | TrustOP | Rel-7 | Silke Holtmanns, Nokia | TSG |  | Silke.Holtmanns@NOKIA.COM | Michael |
| 206 | 42 | Development of UEA2 and UIA2 | 268d? | 2004-12-01 A | 2005-12-09 | 80% | 53.6d? | 2004-12-01 | 2005-12-09 | 268d? | 460d | finish no earlier than 2005-12-09 | S3 | 2144h | 1715.2h | AlgUEA2 | Rel-7 | Per Christoffersson, Teliasonera | TSG |  | per.christoffersson@teliasonera.com | Michael |
| 207 | 43 | Lawful Interception in the 3GPP Rel-7 architecture | 118d? | 2005-06-28 A | 2005-12-08 | 40% | 70.8d? | 2005-06-28 | 2005-12-08 | 118d? | 461d | start no earlier than 2005-06-28 | S3 | 944h | 377.6h | LI-7A | Rel-7 | Berthold Wilhelm, BMWI |  |  | berthold.wilhelm@regtp.de | Mike |
| 208 | 44 | **Support of Conversational Services in A/Gb mode via the PS domain** | 421d? | 2005-04-08 A | 2006-11-17 |  | 421d? | 2005-04-08 | 2006-04-28 | 276d? | 215d |  | GP | 13251.2h | 198.72h | SCSAGB | Rel-7 | Gunnar Hedby, Ericsson |  |  | gunnar.hedby@ericsson.com | Paolo |
| 209 | 44.1 | Definition of radio resource management functionality | 421d? | 2005-04-08 | 2006-11-17 |  |  | 2005-04-08 | 2006-04-28 | 276d? | 215d | finish no earlier than 2006-11-17 | G1 | 3368h |  | SCSAGB-RRM | Rel-7 | Gunnar Hedby, Ericsson |  |  | gunnar.hedby@ericsson.com | Paolo |
| 210 | 44.2 | Radio Channel Support | 421d? | 2005-04-08 | 2006-11-17 |  |  | 2005-04-08 | 2006-04-28 | 276d? | 215d | finish no earlier than 2006-11-17 | G2 | 3368h |  | SCSAGB-RCHS | Rel-7 | Gunnar Hedby, Ericsson |  |  | gunnar.hedby@ericsson.com | Gert |
| 211 | 44.3 | Modifications to FLO | 421d? | 2005-04-08 | 2006-11-17 |  |  | 2005-04-08 | 2006-04-28 | 276d? | 215d | finish no earlier than 2006-11-17 | G2 | 3368h |  | SCSAGB-FLO | Rel-7 | Gunnar Hedby, Ericsson |  |  | gunnar.hedby@ericsson.com | Gert |
| 212 | 45 | **Addition of new frequency band to GSM (T-GSM810)** | 321d? | 2005-04-08 A | 2006-06-30 | 53% | 150.23d? | 2005-04-08 | 2005-11-18 | 161d? | 315d |  | GP | 7232h | 2481.2h | TGSM810 | Rel-7 | Chen De, Huawei |  |  | chende@huawei.com | Paolo |
| 213 | 45.1 | Changes to core specification | 106d? | 2005-04-08 A | 2005-09-02 A | 100% |  | 2005-04-08 | 2005-09-02 | 106d? |  | finish no earlier than 2005-09-02 | GP | 848h | 848h | TGSM810-Core | Rel-7 | Chen De, Huawei |  |  | chende@huawei.com | Paolo |
| 214 | 45.2 | Changes to MS testing specification | 321d? | 2005-04-08 A | 2006-06-30 | 15% | 272.85d? | 2005-04-08 | 2005-11-18 | 161d? | 315d | finish no earlier than 2006-06-30 | G3 | 2568h | 385.2h | TGSM810-MStest | Rel-7 | Chen De, Huawei |  |  | chende@huawei.com | Stoyan |
| 215 | 45.3 | Changes to BTS testing specification | 156d? | 2005-04-08 A | 2005-11-11 A | 100% |  | 2005-04-08 | 2005-09-02 | 106d? |  | finish no earlier than 2005-11-11 | G1 | 1248h | 1248h | TGSM810-BTStest | Rel-7 | Chen De, Huawei |  |  | chende@huawei.com | Paolo |

Notes:
- 192: Text3: New TS 32.xyz
- 193: Text3: 32.405
- 194: Text3: 32.403
- 195: Text3: 32.404,32.405,32.406,32.407
- 196: Text3: 32.403
- 197: Text3: new TS 32.xyz
- 198: Text3: 32.403
- 200: Text3: 32.421,32.422,32.423
- 202: 07/2005: OMA (Stage 1), Stage 2/3 SA5, CT1/3/4 / Text3: 32.101,32.421,32.422,32.423
- 203: Text3: 32.421,32.422,32.423. 3 new TS 32.4x1,2,3
- 204: Text3: 32.421,32.422,32.423
- 205: WID approved SA#26. Record created after SA#27
- 206: WID approved SA#26, Dependant on Funding Availability. Record created after SA#27 / Text3: 35.919, 35.215, 35.216, 35.217, 35.218
- 208: Originally started Nov. 2003 as GP-030443
- 212: Text3: 45.005, 45.050, 24.008, 45.008, 45.001, 43.022, 43.030, 44.018, 44.060, 51.010-1, 51.021
- 213: Text3: 45.005, 45.050, 24.008, 45.008, 45.001, 43.022, 43.030, 44.018, 44.060
- 214: Started / Text3: 51010-1
- 215: Text3: 51021

| ID | WBS | Task | Duration | Start | Finish | Complete | Remaining | Baseline start | Baseline finish | Baseline duration | Total slack | Constraint | Resources | Work | Actual work | Text1 | Text4 | Text5 | Text6 | Text8 | Text3 | Text7 |
| --- | --- | --- | --- | --- | --- | --- | --- | --- | --- | --- | --- | --- | --- | --- | --- | --- | --- | --- | --- | --- | --- | --- |
| 216 | 46 | **Handover of dedicated and shared resources while in dual transfer mode** | 371d? | 2005-04-08 A | 2006-09-08 | 20% | 296.44d? | 2005-04-08 | 2006-11-17 | 421d? | 265d |  | GP | 10352h | 1484h | HODSRDTM | Rami Vaittinen, Nokia | rami.vaittinen@nokia.com | Rel-7 | Paolo |  |  |
| 217 | 46.1 | Handover of dedicated and shared resources while in dual transfer mode | 371d? | 2005-04-08 A | 2006-09-08 | 50% | 185.5d? | 2005-04-08 | 2006-04-28 | 276d? | 265d | finish no earlier than 2006-09-08 | G2 | 2968h | 1484h | HODSRDTM-G2 | Rami Vaittinen, Nokia | rami.vaittinen@nokia.com | Rel-7 | Gert | 43.055, 44.018, 44.060 |  |
| 218 | 46.2 | MS Conformance Testing | 276d? | 2005-04-08 | 2006-04-28 |  |  |  |  |  | 360d | start no earlier than 2005-04-08 | G3 | 2208h |  | HODSRDTM-Mstest | Rami Vaittinen, Nokia | rami.vaittinen@nokia.com | Rel-7 | Stoyan | 51-010 |  |
| 219 | 46.3 | BTS conformance testing | 276d? | 2005-04-08 | 2006-04-28 |  |  | 2005-04-08 | 2006-11-17 | 421d? | 360d | finish no earlier than 2006-04-28 | G1 | 2208h |  | HODSRDTM-BTStest | Rami Vaittinen, Nokia | rami.vaittinen@nokia.com | Rel-7 | Paolo | 51.026 |  |
| 220 | 47 | Future GERAN Evolution | 321d? | 2005-04-08 A | 2006-06-30 | 85% | 48.15d? | 2005-04-08 | 2005-11-11 | 156d? | 315d | finish no earlier than 2006-06-30 | GP | 2568h | 2182.8h | FGE | Eddie Riddington, Nokia Corporation | eddie.riddington@nokia.com | Rel-7 | Paolo |  |  |
| 221 | 48 | 3G-324M Video Telephony Call Setup Times Improvements | 341d? | 2005-06-08 A | 2006-09-27 | 55% | 153.45d? | 2005-06-08 | 2006-09-27 | 341d? | 252d | finish no earlier than 2006-09-27 | S4 | 2728h | 1500.4h | VTCSTI | Edward Hall (Vodafone) | edward.hall@vodafone.co.uk | Rel-7 | Paolo | 26.abc |  |
| 222 | 49 | **Identification of Communication Services in IMS** | 425d? | 2005-05-02 A | 2006-12-15 | 52% | 204.94d? | 2005-05-02 | 2006-09-08 | 355d? | 195d |  | S2 | 7896h | 2456h | ServID | Stephen Terrill, Ericsson | stephen.terrill@ericsson.com | Rel-7 | Maurice | 23.228, 23.218, 23.125 |  |
| 223 | 49.1 | TR for ICS | 232d? | 2005-05-02 A | 2006-03-21 A | 100% |  | 2005-05-02 | 2006-03-21 | 232d? |  | finish no earlier than 2006-03-20 | S2 | 1856h | 1856h | ServID |  |  | Rel-7 |  | 23.816 |  |
| 224 | 49.2 | Stage 2 for ICS | 144d? | 2005-11-11 A | 2006-05-31 | 41% | 85d? | 2006-03-27 | 2006-09-08 | 120d? | 337d | start no earlier than 2005-11-11 | S2 | 1152h | 472h | ServID |  |  | Rel-7 |  |  |  |
| 225 | 49.3 | SA5 Charging aspects of ServID | 186d? | 2006-03-31 | 2006-12-15 |  |  |  |  |  | 195d | finish no earlier than 2006-12-15 | S5 | 1488h |  | ServID-CH | Telefonica | Catalán, Daniel | Rel-7 | Adrian | 32.260, 32.272, 32.298, 32.299 |  |
| 226 | 50 | **VoIMS bearer related enhancements** | 354d? | 2005-03-15 A | 2006-07-21 | 60% | 142.42d? | 2005-03-15 | 2006-07-21 | 354d? | 300d |  | S2 | 6863.2h | 2472h | VoIMS |  |  | Rel-7 |  |  |  |
| 227 | 50.1 | FS on enhancement of radio performance for VoIMS | 320d? | 2005-05-02 A | 2006-07-21 | 35% | 208d? | 2005-05-02 | 2006-07-21 | 320d? | 300d | finish no earlier than 2006-07-21 | S2 | 2560h | 896h | VoIMS | Laurence Lautier, Nortel Networks | lautierl@nortel.com | Rel-7 | Maurice | 23.807 |  |
| 228 | 50.2 | Improved support of IMS Realtime Services using HSDPA/HSUPA | 197d? | 2005-03-15 A | 2005-12-14 A | 100% |  | 2005-03-15 | 2005-12-14 | 197d? |  | start no earlier than 2005-03-15 | R2 | 1576h | 1576h | RANimp-IMSRealTime | Don Zelmer | don.zelmer@CINGULAR.COM | Rel-7 | MCC_RAN |  | TSG |
| 229 | 51 | Performance Characterization of VoIMS over HSDPA\EUL channels | 402d? | 2005-03-15 A | 2006-09-27 | 10% | 361.8d? | 2005-03-15 | 2006-03-15 | 262d? | 252d | finish no earlier than 2006-09-27 | S4 | 3216h | 321.6h | VoIMS-PCVoIMS | Dimitris Vasilaras (Lucent Technologies) | dvasilaras@lucent.com | Rel-7 | Paolo | 26.935 | TSG |
| 230 | 52 | **Optimizations for Multimedia Telephony over IMS** | 261d? | 2005-09-28 A | 2006-09-27 | 35% | 169.65d? | 2005-09-28 | 2006-09-27 | 261d? | 252d |  | S4 | 4176h | 1461.6h | OMTIMS | Olle Franceschi (Ericsson) | olle.franceschi@ericsson.com | Rel-7 | Paolo | 26.235, 26.236 |  |
| 231 | 52.1 | Characterisation of Adaptive Jitter Management Performance for VoIP Services | 261d? | 2005-09-28 A | 2006-09-27 | 35% | 169.65d? | 2005-09-28 | 2006-09-27 | 261d? | 252d | finish no earlier than 2006-09-27 | S4 | 2088h | 730.8h | OMTIMS-CAJMP | David Huo (Lucent Technologies) | dhuo@lucent.com | Rel-7 | Paolo |  |  |
| 232 | 53 | End-to-End Multimedia Services Performance Metrics | 261d? | 2005-09-28 | 2006-09-27 |  |  | 2005-09-28 | 2006-09-27 | 261d? | 252d | finish no earlier than 2006-09-27 | S4 | 2088h |  | E2EMSPM | Zhang Yan (China Mobile) | zhangyanyf@chinamobile.com | Rel-7 | Paolo |  |  |
| 233 | 54 | **Supporting Globally Routable User Agent URIs in IMS** | 220d? | 2005-11-14 A | 2006-09-15 | 21% | 174.27d? | 2005-10-10 | 2006-10-20 | 0d? | 260d |  | S2 | 2232h | 464h | GRUU | Adrian Buckley (Research In Motion) | abuckley@rim.com | Rel-7 | Maurice | 23.8XX, 22.228, 23.228, 23.218, 24.229 |  |
| 234 | 54.1 | TR on GURU | 219d? | 2005-11-14 A | 2006-09-14 | 26% | 161d? |  |  |  | 261d | finish no earlier than 2006-09-14 | S2 | 1752h | 464h | GRUU |  |  | Rel-7 |  |  |  |
| 235 | 54.2 | Stage 2 on GURU | 60d? | 2006-06-26 | 2006-09-15 |  |  |  |  |  | 260d | finish no earlier than 2006-09-15 | S2 | 480h |  | GRUU |  |  | Rel-7 |  |  |  |
| 236 | 55 | ISIM API for Java Card | 200d? | 2005-03-14 A | 2005-12-16 | 90% | 20d? |  |  |  | 455d | finish no earlier than 2005-12-16 | C6 | 1600h | 1440h | APIJAVA | Sebastian Hans, Sun Microsystems Ltd. |  | Rel-7 | Gaby | 31.103, TS 102 241 |  |
| 237 | 56 | **Rel7 Security enhancements** | 130d? | 2005-09-12 A | 2006-03-10 | 82% | 22.91d? |  |  |  | 395d |  | S3 | 2584h | 2128.52h | SEC7 |  |  | Rel-7 |  |  |  |
| 238 | 56.1 | HTTPS connection between a UICC and a NAF | 1d? | 2005-09-12 A | 2005-09-12 A | 100% |  |  |  |  |  | start no earlier than 2005-09-12 | S3 | 8h | 8h | SEC7-HSUN | Jacques Seif (Axlato) | JSeif@axalto.com | Rel-7 |  | 33.222, 24.109, 33.918 |  |
| 239 | 56.2 | 2G GBA: 2G SIM usage in 3GPP GAA framework | 61d? | 2005-09-12 A | 2005-12-05 | 98% | 1.22d? |  |  |  | 464d | finish no earlier than 2005-12-05 | S3 | 488h | 478.24h | SEC7-2GGBA | Silke Holtmanns (Nokia) | Silke.Holtmanns@nokia.com | Rel-7 |  | 33.220, 33.290 |  |
| 240 | 56.3 | Generic Authentication Architecture usage extensions and optimisations | 1d? | 2005-09-12 A | 2005-09-12 | 70% | 0.3d? |  |  |  | 524d | start no earlier than 2005-09-12 | S3 | 8h | 5.6h | SEC7-GAA2 | Silke Holtmanns (Nokia) | Silke.Holtmanns@nokia.com | Rel-7 |  | 33.220, 29.109 |  |
| 241 | 56.4 | Network Domain Security; SS7 security Gateway (NDS/TCAPsec) | 130d? | 2005-09-12 A | 2006-03-10 | 75% | 32.5d? |  |  |  | 395d | finish no earlier than 2006-03-10 | S3 | 1040h | 780h | SEC7-NDS-TCAPsec | Marc Blommaert (Siemens) | marc.blommaert@siemens.com | Rel-7 |  | 33.200, 33.204 |  |
| 242 | 57 | IMS Service Brokering enhancements | 69d? | 2005-12-07 A | 2006-03-13 A | 100% |  | 2005-11-04 | 2006-06-16 | 161d? |  | finish no earlier than 2006-03-13 | S1 | 552h | 552h | ISB | John-Luc Bakker (Telcordia) | jbakker@telcordia.com | Rel-7 | Michael | 22.228 |  |
| 243 | 58 | Network Composition | 211d? | 2005-12-07 A | 2006-09-27 | 5% | 200.45d? |  |  |  | 252d | finish no earlier than 2006-09-27 | S1 | 1688h | 84.4h | NetComp | Joerg Swetina (Siemens) | joerg.swetina@siemens.com | Rel-7 |  | 22.xxx |  |
| 244 | 59 | Key establishment between a UICC and a terminal | 201.45d? | 2005-12-07 A | 2006-09-28 | 5% | 191.38d? |  |  |  | 251d | finish no earlier than 2006-09-28 | S3 | 1611.6h | 80.58h | KeyEstUTerm | Mireille Pauliac (Gemplus) | mireille.pauliac@gemplus.com | Rel-7 |  | 33.xxx |  |

Notes:
- 216: Started at GERAN#24
- 217: Started at GERAN#24
- 218: Not started
- 219: Not started
- 220: FS started
- 221: Conditionally, in the event Phase 2 is needed, end is Dec.06
- 222: WID approved SA#28
- 225: 03/2006 SA#31 WID approved
- 226: Created by MCC to group all VoIMS related items, after consultation of chairs
- 227: WID approved SA#28
- 229: Started
- 233: Approved at SP#29

| ID | WBS | Task | Duration | Start | Finish | Complete | Remaining | Baseline start | Baseline finish | Baseline duration | Total slack | Constraint | Resources | Work | Actual work | Text1 | Text3 | Text4 | Text5 | Text6 | Text8 | Text7 |
| --- | --- | --- | --- | --- | --- | --- | --- | --- | --- | --- | --- | --- | --- | --- | --- | --- | --- | --- | --- | --- | --- | --- |
| 245 | 60 | **Mobile Station Receive Diversity (DARP Phase II)** | 311d? | 2005-11-11 A | 2007-01-19 | 3% | 300.96d? |  |  |  | 170d |  | GP | 10920h | 352.67h | MSRD2 | 24.008, 45.005, 51.010 | Kent Pedersen, Nokia Corporation (ETSI) | kent.pedersen@nokia.com | Rel-7 | Paolo |  |
| 246 | 60.1 | MS conformance test of DARP Phase II (MSRD) | 311d? | 2005-11-11 | 2007-01-19 |  |  |  |  |  | 170d | finish no earlier than 2007-01-19 | GP | 2488h |  | MSRD2-Msconf | 51.010 | Kent Pedersen, Nokia Corporation (ETSI) | kent.pedersen@nokia.com | Rel-7 | Paolo, Stoyan |  |
| 247 | 60.2 | Performance Requirements for Mobile Station Receive Diversity, DARP Phase II | 216d? | 2005-11-11 A | 2006-09-08 | 10% | 194.4d? |  |  |  | 265d | finish no earlier than 2006-09-08 | GP | 1728h | 172.8h | MSRD2-PerfReq | 45.005 | Kent Pedersen, Nokia Corporation (ETSI) | kent.pedersen@nokia.com | Rel-7 | Paolo |  |
| 248 | 60.3 | Capability signalling of Mobile Station Receive Diversity, DARP Phase II | 216d? | 2005-11-11 | 2006-09-08 |  |  |  |  |  | 265d | finish no earlier than 2006-09-08 | GP | 1728h |  | MSRD2-CapSig | 24.008 | Kent Pedersen, Nokia Corporation (ETSI) | kent.pedersen@nokia.com | Rel-7 | Paolo, Gert |  |
| 249 | 60.4 | Test Scenarios for Mobile Station Receive Diversity, DARP Phase II | 311d? | 2005-11-11 A | 2007-01-19 | 4% | 298.56d? |  |  |  | 170d | finish no earlier than 2007-01-19 | GP | 2488h | 99.52h | MSRD2-TestSc | 45.005 | Kent Pedersen, Nokia Corporation (ETSI) | kent.pedersen@nokia.com | Rel-7 | Paolo |  |
| 250 | 61 | MBMS User Service Extensions | 261d? | 2005-12-07 A | 2006-12-06 | 10% | 234.9d? |  |  |  | 202d | finish no earlier than 2006-12-06 | S4 | 2088h | 208.8h | MBMSUSE | 26.346, 26.946 | Thorsten Lohmar (Ericsson) | Thorsten.Lohmar@ericsson.com | Rel-7 | Paolo |  |
| 251 | 62 | IMS Support of Conferencing and Messaging Group Management | 221d? | 2005-11-04 A | 2006-09-08 | 25% | 165.75d? |  |  |  | 265d | finish no earlier than 2006-09-08 | C1 | 1768h | 442h | IMSconf |  | Keith Drage (Lucent) |  | Rel-7 | Andrijana |  |
| 252 | 63 | (Small) Technical Enhancements and Improvements for Rel-7 | 400d? | 2005-06-06 | 2006-12-15 |  |  |  |  |  | 195d | finish no earlier than 2006-12-15 | All | 3200h |  | TEI7 |  |  |  | Rel-7 |  |  |
| 253 | 64 | **Selective Disabling of UE Capabilities** | 489.36d? | 2005-01-24 A | 2006-12-08 | 82% | 89.09d? | 2005-01-24 | 2006-12-08 | 489.36d? | 200d |  | S1 | 9356.8h | 7653.43h | SDoUE | 22.xxx | Nigel Barnes (Motorola Ltd) | Nigel.Barnes@motorola.com | Rel-7 | Michael | TSG |
| 254 | 64.1 | Stage 1 | 393.6d? | 2005-01-24 A | 2006-12-08 A | 100% |  | 2005-01-24 | 2006-12-08 | 393.6d? |  | finish no earlier than 2006-12-08 | S1 | 3148.8h | 3148.8h | SDoUE-CRs | 22.011 | Nigel Barnes (Motorola Ltd) | Nigel.Barnes@motorola.com | Rel-7 | Michael | TSG |
| 255 | 64.2 | TR on different possible architectures | 195d? | 2005-03-21 A | 2005-12-16 A | 100% |  | 2005-03-21 | 2005-12-16 | 195d? |  | finish no earlier than 2005-12-16 | S2 | 1560h | 1560h | SDoUE | 23.805 |  |  | Rel-7 | Maurice |  |
| 256 | 64.3 | Stage 3 of SDoUE | 131d? | 2006-03-10 | 2006-09-08 |  |  |  |  |  | 265d | finish no earlier than 2006-09-08 | C1 | 1048h |  | SDouE | New TS 24.305 | Christian Herrero (Ericsson) | christian.herrero@ericsson.com | Rel-7 | Andrijana |  |
| 257 | 65 | **Personal Network Management (PNM)** | 276d? | 2005-07-11 A | 2006-07-31 | 91% | 25.79d? | 2005-07-11 | 2005-12-08 | 101.2d? | 294d |  | S1 | 5689.6h | 5157.88h | PNPAN |  | Armin Toepfer, Vodafone | armin.toepfer@vodafone.com | Rel-7 | Mike |  |
| 258 | 65.1 | Study of PNPAM | 167d? | 2005-07-11 A | 2006-02-28 A | 100% |  |  |  |  |  | start no earlier than 2005-07-11 | S1 | 1336h | 1336h |  |  |  |  |  |  |  |
| 259 | 65.2 | Stage 1 of PNPAM | 276d? | 2005-07-11 A | 2006-07-31 | 85% | 41.4d? |  |  |  | 294d | start no earlier than 2005-07-11 | S1 | 2208h | 1876.8h |  | 22.259 |  |  |  |  |  |
| 260 | 66 | **Multimedia Telephony Capabilities for IMS** | 320d? | 2005-07-11 A | 2006-09-29 | 25% | 240.82d? | 2005-07-11 | 2005-12-08 | 101.2d? | 250d |  | S1 | 7137.6h | 1766.18h | MITE |  | Peter Bleckert, Ericsson | peter.bleckert @ericsson.com | Rel-7 | Mike |  |
| 261 | 66.1 | Study of (MITe) - IMS Multimedia Telephony Communication Enabler and supplementary services | 276d? | 2005-07-11 A | 2006-07-31 | 52% | 132.48d? |  |  |  | 294d | start no earlier than 2005-07-11 | S1 | 2208h | 1148.16h |  | 22.973 | Peter Bleckert, Ericsson | peter.bleckert @ericsson.com |  | Mike |  |
| 262 | 66.2 | IMS Multimedia Telephony Service | 173d? | 2006-02-01 | 2006-09-29 |  |  |  |  |  | 250d | start no earlier than 2006-02-01 | S1 | 1384h |  |  | 22.173 | Peter Bleckert, Ericsson | peter.bleckert @ericsson.com |  | Mike |  |
| 263 | 66.3 | Stage 3 of MITE | 131d? | 2006-03-10 | 2006-09-08 |  |  |  |  |  | 265d | finish no earlier than 2006-09-08 | C1 | 1048h |  | MITE | New TS 24.173 | Alf Heidermark (Ericsson) | alf.heidermark@ericsson.com | Rel-7 | Andrijana |  |
| 264 | 67 | **Multimedia interworking between IMS and CS networks** | 181d? | 2005-09-23 A | 2006-06-02 | 71% | 52.73d? | 2005-09-23 | 2006-06-02 | 181d? | 335d |  | C3 | 3287.99h | 1347.43h | MIW-IMS | 29.163 | Nico Gabriele, Vodafone UK | nico.gabriele@vodafone.com | Rel-7 | Seung Don |  |
| 265 | 67.1 | Stages 1 and 2 defined in earlier Release | 49d? | 2005-09-23 A | 2005-11-30 A | 100% |  |  |  |  |  | start no earlier than 2005-09-23 | C3 | 392h | 392h |  |  |  |  |  |  |  |
| 266 | 67.2 | Stage 3 | 181d? | 2005-09-23 A | 2006-06-02 | 63% | 67d? |  |  |  | 335d | start no earlier than 2005-09-23 | C3 | 1448h | 912h |  |  |  |  |  |  |  |
| 267 | 68 | **Multimedia Telephony Service for IMS** | 191d? | 2006-03-15 A | 2006-12-06 |  | 191d? |  |  |  | 202d |  | S1 | 4584h | 8h | MTSI |  | Peter Bleckert, Ericsson | peter.bleckert @ericsson.com | Rel-7 | Mike |  |
| 268 | 68.1 | IMS Multimedia Telephony Service -Stage 1 | 191d? | 2006-03-15 | 2006-12-06 |  |  |  |  |  | 202d | start no earlier than 2006-03-15 | S1 | 1528h |  | MTSI-REQ | 22.173 | Peter Bleckert, Ericsson | peter.bleckert @ericsson.com | Rel-7 | Mike |  |
| 269 | 68.2 | IMS Multimedia Telephony; media handling and interaction | 191d? | 2006-03-15 | 2006-12-06 |  |  |  |  |  | 202d | finish no earlier than 2006-12-06 | S4 | 1528h |  | MTSI-MHI | 26.235, 26,236 | Olle Franceschi, Ericsson | olle.franceschi@ericsson.com | Rel-7 | Paolo |  |
| 270 | 69 | Network selection enhancements | 191d? | 2006-03-15 A | 2006-12-06 | 42% | 110.5d? | 2005-11-04 | 2006-06-16 | 161d? | 202d | finish no earlier than 2006-12-06 | S1 | 1528h | 644h | NSP-CR | 22.101, 22.011, 23.122, 24.008, 25.304, 31.102, 45.008 | Chris Friel, O2 | chris.friel@o2.com | Rel-7 | Michael |  |
| 271 | 70 | Enhancements for VGCS Applications | 191d? | 2006-03-15 A | 2006-12-06 | 10% | 171.9d? |  |  |  | 202d | finish no earlier than 2006-12-06 | S1 | 1528h | 152.8h | EVA | 42.068 | Amar Deol, Nortel Networks | deola@nortel.com | Rel-7 | Michael |  |

Notes:
- 253: Moved from FS section Feb 06
- 254: Moved from FS section Feb 06
- 255: Moved from FS section Feb 06
- 257: Moved from FS section Feb 06
- 258: Moved from FS section Feb 06
- 259: Moved from FS section Feb 06
- 260: Moved from FS section Feb 06
- 263: TS 24.173:IMS Multimedia telephony service and supplementary services
- 264: Moved from FS section Feb 06
- 265: Moved from FS section Feb 06

| ID | WBS | Task | Duration | Start | Finish | Complete | Remaining | Baseline start | Baseline finish | Baseline duration | Total slack | Constraint | Resources | Work | Actual work | Text1 | Text3 | Text4 | Text5 | Text6 | Text8 | Text12 | Text7 |
| --- | --- | --- | --- | --- | --- | --- | --- | --- | --- | --- | --- | --- | --- | --- | --- | --- | --- | --- | --- | --- | --- | --- | --- |
| 272 | 71 | **Interoperability between VGCS/VBS and A/Gb flexibility** | 133d? | 2006-03-22 | 2006-09-22 |  |  |  |  |  | 255d |  | C1 | 3192h |  | VGCSFlex | 43.068, 43.069, 29.002 | Robert Zaus (Siemens) | robert.zaus@siemens.com | Rel-7 | Andrijana |  |  |
| 273 | 71.1 | CT1 aspects of VGCSFlex | 133d? | 2006-03-22 | 2006-09-22 |  |  |  |  |  | 255d | finish no earlier than 2006-09-22 | C1 | 1064h |  |  | 43.068, 43.069 |  |  | Rel-7 |  |  |  |
| 274 | 71.2 | CT4 aspects of VGCSFlex | 133d? | 2006-03-22 | 2006-09-22 |  |  |  |  |  | 255d | finish no earlier than 2006-09-22 | C4 | 1064h |  |  | 29.002 |  |  | Rel-7 |  |  |  |
| 275 | 72 | One Tunnel solution for Optimisation of Packet Data Traffic | 133d? | 2006-03-22 | 2006-09-22 |  |  |  |  |  | 255d | start no earlier than 2006-03-22 | S2 | 1064h |  |  |  | Antti Pasanen (Nokia) |  |  | Maurice |  |  |
| 276 | 73 | **DELETE - PS domain and IMS support for IMS Emergency sessions** | 185d? | 2005-10-10 | 2006-06-23 |  |  | 2005-10-10 | 2006-06-23 | 185d? | 320d |  | S2 | 1940.97h |  | IMS-EMER | 23.867, TS 23.abc, 23.060, 23.002, 23.271 | Curt Wong (Nokia) | curt.c.wong@nokia.com | Rel-7 | Maurice | SP-30 |  |
| 277 | 73.1 | DELETE IMS aspects to support IMS Emergency sessions | 121.31d? | 2005-10-10 | 2006-06-23 |  |  | 2005-10-10 | 2006-06-23 | 121.31d? | 320d | finish no earlier than 2006-06-23 | S2 | 970.48h |  | IMS-EMER | 23.867, TS 23.abc, 23.060, 23.002, 23.271 | Curt Wong (Nokia) | curt.c.wong@nokia.com | Rel-7 | Maurice | SP-30 | TSG |
| 278 | 73.2 | DELETE PS domain aspects to support IMS Emergency sessions | 121.31d? | 2005-10-10 | 2006-06-23 |  |  | 2005-10-10 | 2006-06-23 | 121.31d? | 320d | finish no earlier than 2006-06-23 | S2 | 970.48h |  | IMS-EMER | 23.867, TS 23.abc, 23.060, 23.002, 23.271 | Curt Wong (Nokia) | curt.c.wong@nokia.com | Rel-7 | Maurice | SP-30 | TSG |
| 279 | 74 | DELETED- Covered by SI - Personal Network (PN) and Personal Area Network (PAN) | 101.2d? | 2005-07-11 A | 2005-12-08 | 70% | 30.36d? | 2005-07-11 | 2005-12-08 | 101.2d? | 461d | finish no earlier than 2005-12-08 | S1 | 809.6h | 566.72h | PNPAN |  | Armin Toepfer, Vodafone | armin.toepfer@vodafone.com | Rel-7 | Mike | SP-30 |  |
| 280 | 75 | DELETED- Covered by SI - Multimedia Telephony Capabilities for IMS | 101.2d? | 2005-07-11 A | 2005-12-08 | 70% | 30.36d? | 2005-07-11 | 2005-12-08 | 101.2d? | 461d | finish no earlier than 2005-12-08 | S1 | 809.6h | 566.72h | MITE |  | Peter Bleckert, Ericsson | peter.bleckert @ericsson.com | Rel-7 | Mike | SP-30 |  |
| 281 | 76 | DELETED- Covered by SI - Transferring of emergency Call data | 109d? | 2005-07-11 A | 2005-12-08 | 70% | 32.7d? | 2005-07-11 | 2005-12-08 | 109d? | 461d | finish no earlier than 2005-12-08 | S1 | 872h | 610.4h | eCALL |  | Steve Vardy, (Motorola S.A.S) | steven.vardy@motorola.com | Rel-7 | Mike | SP-30 |  |
| 282 | 77 | DELETED- Covered by SI - MBMS Enhancements | 109d? | 2005-07-11 A | 2005-12-08 | 20% | 87.2d? | 2005-07-11 | 2005-12-08 | 109d? | 461d | finish no earlier than 2005-12-08 | S1 | 872h | 174.4h | MBMSE |  | Liu Hong, China Mobile | liuhongyfw@chinamobile.com | Rel-7 | Mike | SP-30 |  |
| 283 | 78 | Rel-7 Feasibility Studies listed below | 1d? | 2000-01-03 | 2000-01-03 |  |  | 2000-01-03 | 2000-01-03 | 1d? | 2009d |  | CT;RAN;SA | 8h |  |  |  |  |  | Rel-7 |  |  |  |
| 284 | 79 | Study Item on IMS enhancements and optimisations for real time communication. | 234d? | 2005-10-10 A | 2006-08-31 | 44% | 131d? |  |  |  | 271d | start no earlier than 2005-10-10 | S2 | 1872h | 824h | IMS-RT | 23.818 | Stephen Terrill (Ericsson) | stephen.terrill@ericsson.com | Rel-7 | Maurice |  |  |
| 285 | 80 | Behaviour of Multi system UEs | 480d? | 2004-06-28 A | 2006-04-28 | 90% | 48d? | 2004-06-28 | 2005-03-16 | 188d? | 360d | start no earlier than 2004-06-28 | S1 | 3840h | 3456h | BMSU | 22.936 | D Williams (QUALCOMM) | dwilliams@qualcomm.com | Rel-7 | Michael |  | TSG |
| 286 | 81 | **FS on IMS with real time services deployment** | 384d? | 2004-06-28 A | 2005-12-15 | 99% | 0d? | 2004-06-28 | 2005-12-15 | 384d? | 0d |  | S1 | 8672h | 6304.24h | IRTSD |  |  |  | Rel-7 | Maurice |  | TSG |
| 287 | 81.1 | Feasibility Study on Combining CS calls and IMS sessions | 384d? | 2004-06-28 A | 2005-12-15 A | 100% |  | 2004-06-28 | 2005-12-15 | 384d? |  | start no earlier than 2004-06-28 | S1 | 3072h | 3072h | IRTSD-CS_IMS | 22.979, 23.899 |  |  | Rel-7 | Michael |  | TSG |
| 288 | 81.2 | TR on Stage 2 (IMS services using CS bearers) | 316d? | 2004-06-28 A | 2005-09-12 A | 100% |  | 2004-06-28 | 2005-09-12 | 316d? |  | finish no earlier than 2005-09-12 | S2 | 2528h | 2528h | IRTSD-IMSCS | 23.899 | Mark Watson (Nortel Networks) |  | Rel-7 | Maurice |  | TSG |
| 289 | 82 | TR on CSI interworking related aspects | 190d? | 2006-01-09 A | 2006-09-29 | 20% | 152d? |  |  |  | 250d | start no earlier than 2006-01-09 | S2 | 1520h | 304h | CSIterm |  | Osok Song (Samsung) |  | Rel-7 | Maurice |  |  |
| 290 | 83 | **All-IP Network (AIPN)** | 448d? | 2004-06-28 A | 2006-03-15 A | 100% |  | 2004-06-28 | 2006-03-15 | 448d? |  |  | S1 | 8672h | 8672h | AIPN | 22.978 | Chris Sachno (NTT DoCoMo) | c.masyu@nttdocomo.co.jp | Rel-7 | Michael |  | TSG |
| 291 | 83.1 | All-IP Network Feasibility Study | 188d? | 2004-06-28 A | 2005-03-16 A | 100% |  | 2004-06-28 | 2005-03-16 | 188d? |  | start no earlier than 2004-06-28 | S1 | 1504h | 1504h | AIPFS | 22.978 | Chris Sachno (NTT DoCoMo) | c.masyu@nttdocomo.co.jp | Rel-7 | Michael |  | TSG |
| 292 | 83.2 | Stage1 | 448d? | 2004-06-28 A | 2006-03-15 A | 100% |  | 2004-06-28 | 2006-03-15 | 448d? |  | finish no earlier than 2006-03-15 | S1 | 3584h | 3584h | AIPN | 22.258 | Chris Sachno (NTT DoCoMo) | c.masyu@nttdocomo.co.jp | Rel-7 | Michael |  | TSG |
| 293 | 84 | **3GPP System Architecture Evolution** | 466d? | 2004-12-03 A | 2006-09-15 | 59% | 191.77d? | 2004-12-03 | 2006-06-16 | 401d? | 260d |  | S2 | 9832h | 5785.8h | SAE |  |  |  | Rel-7 |  |  | TSG |
| 294 | 84.1 | Stage 2 Interim conclusion for RAN Work to start | 211d? | 2004-12-03 A | 2005-09-23 A | 100% |  | 2004-12-03 | 2005-09-23 | 211d? |  | finish no earlier than 2005-09-23 | S2 | 1688h | 1688h | SAE | 23.882 |  |  | Rel-7 |  |  |  |
| 295 | 84.2 | Stage 2 Feasibility study on 3GPP architectural development | 466d? | 2004-12-03 A | 2006-09-15 | 51% | 228d? | 2004-12-03 | 2006-06-16 | 401d? | 260d | finish no earlier than 2006-09-15 | S2 | 3728h | 1904h | SAE | 23.882 |  |  | Rel-7 |  |  |  |
| 296 | 84.3 | Security study for Inter-access mobility between non 3GPP and 3GPP system | 86d? | 2006-02-03 | 2006-06-02 |  |  | 2006-02-03 | 2006-06-02 | 86d? | 335d | start no earlier than 2006-02-03 | S3 | 688h |  | SAE-Sec | 23.882 |  |  | Rel-7 |  |  |  |
| 297 | 85 | FS on Performance Evaluation of the UE behaviour in high speed trains with speeds up to 350 kmph | 328d? | 2005-03-15 A | 2006-06-15 | 85% | 49.2d? | 2005-03-15 | 2006-03-15 | 261d? | 326d | finish no earlier than 2006-06-15 | R4 | 2624h | 2230.4h | RANFS-HSTrains |  | Mike Vogel | Mike.vogel@vodafone.com | Rel-7 | MCC_RAN |  | TSG |
| 298 | 86 | FS of enhanced support of Video Telephony DELETE | 481d? | 2004-08-27 A | 2006-06-30 | 35% | 312.65d? | 2004-08-27 | 2005-11-11 | 316d? | 315d | finish no earlier than 2006-06-30 | GP | 3848h | 1346.8h | VIDGER |  | Stefan Eriksson, Ericsson | stefan.g.eriksson@ericsson.com | Rel-7 | Paolo |  | TSG |
| 299 | 87 | FS on Evolved UTRA and UTRAN | 130d? | 2004-12-15 A | 2005-06-15 | 60% | 52d? | 2004-12-15 | 2005-06-15 | 130d? | 588d | finish no earlier than 2005-06-15 | RP | 1040h | 624h | RANFS-Evo |  | Takehiro Nakamura (NTT DoCoMo) | nakamurata@NTTDOCOMO.CO.JP | Rel-7 | MCC_RAN |  | TSG |

Notes:
- 276: Approved at SP#29
- 277: Approved at SP#29
- 278: Approved at SP#29
- 284: Approved at SP#29. To be shown as feature - END Sept 06
- 285: The WID still calls it a BB, not a Feature.
- 294: RAN work started
- 298: FS CLOSED at G#28 (no input)

| ID | WBS | Task | Duration | Start | Finish | Complete | Remaining | Baseline start | Baseline finish | Baseline duration | Total slack | Constraint | Resources | Work | Actual work | Text1 | Text4 | Text5 | Text6 | Text7 | Text8 | Text3 | Text12 |
| --- | --- | --- | --- | --- | --- | --- | --- | --- | --- | --- | --- | --- | --- | --- | --- | --- | --- | --- | --- | --- | --- | --- | --- |
| 300 | 88 | **Study on Videotelephony teleservice** | 231d? | 2005-03-01 A | 2006-01-17 A | 100% |  | 2005-03-15 | 2006-12-06 | 452d? |  |  | S1 | 3696h | 3696h | VidTel | Kurt Bischinger (T-Mobile) | kurt.bischinger@t-mobile.at | Rel-7 | TSG | Michael |  |  |
| 301 | 88.1 | Study on Videotelephony service requirements | 231d? | 2005-03-01 A | 2006-01-17 A | 100% |  | 2005-03-15 | 2006-12-06 | 452d? |  | start no earlier than 2005-03-01 | S1 | 1848h | 1848h | VidTel | Kurt Bischinger (T-Mobile) | kurt.bischinger@t-mobile.at | Rel-7 | TSG | Michael | 22.903 |  |
| 302 | 89 | **Study of Network Selection Principles** | 193d? | 2005-03-15 A | 2005-12-08 | 99% | 0d? | 2005-03-15 | 2005-12-08 | 193d? | 0d |  | S1 | 3088h | 2658.02h | NetSel | Chris Friel (O2) | chris.friel@o2.com | Rel-7 | TSG | Michael |  |  |
| 303 | 89.1 | Review of Network Selection Principles | 193d? | 2005-03-15 A | 2005-12-08 A | 100% |  | 2005-03-15 | 2005-12-08 | 193d? |  | finish no earlier than 2005-12-08 | S1 | 1544h | 1544h | NetSel | Chris Friel (O2) | chris.friel@o2.com | Rel-7 | TSG | Michael | 22.811 |  |
| 304 | 90 | FS on Continuous connectivity for packet data users | 132d? | 2005-03-15 A | 2005-09-15 A | 100% |  | 2005-03-15 | 2005-09-15 | 132d? |  | finish no earlier than 2005-09-15 | R1 | 1056h | 1056h | RANFS-cont-packet | Joerg Gustrau | joerg.gustrau@siemens.com | Rel-7 | TSG | MCC_RAN |  |  |
| 305 | 91 | FS on UTRA Tower Mounted Amplifier (FDD) | 195d? | 2005-06-15 A | 2006-03-14 A | 100% |  | 2005-06-15 | 2006-03-15 | 195d? |  | finish no earlier than 2006-03-15 | R4 | 1560h | 1560h | RANFS-TMA | Klas Sjerling | Klas.Sjerling@ericsson.com | Rel-7 | TSG | MCC_RAN |  |  |
| 306 | 92 | Multimedia Priority Service | 851d? | 2003-03-28 A | 2006-06-30 | 87% | 107d? | 2003-03-28 | 2004-12-16 | 450d? | 315d | finish no earlier than 2005-12-16 | S1 | 6808h | 5952h | PRIOR-MM | Jim Garrahan (Telcordia) | jgarraha@telcordia.com | Rel-6 |  | Michael | 22.953 |  |
| 307 | 93 | Transferring of emergency Call data | 190d? | 2005-07-11 A | 2006-03-31 | 85% | 28.5d? | 2005-07-11 | 2005-12-08 | 109d? | 380d | finish no earlier than 2005-12-08 | S1 | 1520h | 1292h | eCALL | Steve Vardy, (Motorola S.A.S) | steven.vardy@motorola.com | Rel-7 |  | Mike |  |  |
| 308 | 94 | MBMS Enhancements | 109d? | 2005-07-11 A | 2005-12-08 | 25% | 81.75d? | 2005-07-11 | 2005-12-08 | 109d? | 461d | finish no earlier than 2005-12-08 | S1 | 872h | 218h | MBMSE | Liu Hong, China Mobile | liuhongyfw@chinamobile.com | Rel-7 |  | Mike |  |  |
| 309 | 95 | IMS security extensions | 118d? | 2005-06-28 A | 2005-12-08 | 60% | 47.2d? | 2005-06-28 | 2005-12-08 | 118d? | 461d | start no earlier than 2005-06-28 | S3 | 944h | 566.4h | IMS-SE | Bengt Sahlin, Ericsson | Bengt.Sahlin@ericsson.com | Rel-7 |  | Mike |  |  |
| 310 | 96 | Study of a SMS Centre for MT SMS | 191d? | 2005-10-07 A | 2006-06-30 | 44% | 107d? | 2005-10-07 | 2006-03-17 | 116d? | 315d | start no earlier than 2005-10-07 | C4 | 1528h | 672h | SMS7 | Nick Russell, Vodafone UK | Nick.Russell@vodafone.com | Rel-7 |  | Kimmo | 23.840 |  |
| 311 | 97 | Delete was duplicated- Study of Customised Alerting Tone (CAT) Requirements | 191d? | 2005-10-07 A | 2006-06-30 | 20% | 152.8d? |  |  |  | 315d | start no earlier than 2005-10-07 | S1 | 1528h | 305.6h | CAT |  |  | Rel-7 |  |  |  | SP-31 |
| 312 | 98 | Facilitating Machine to Machine Communication in GSM and UMTS (M2M) | 161d? | 2005-11-04 A | 2006-06-16 | 25% | 120.75d? |  |  |  | 325d | finish no earlier than 2006-06-16 | S1 | 1288h | 322h | M2M | Juergen Merkel, Siemens AG |  | Rel-7 |  | Michael | 22.868 |  |
| 313 | 99 | FS on Improvement of the Multimedia Broadcast Multicast Service (MBMS) in UTRAN | 197d? | 2005-12-15 A | 2006-09-15 | 25% | 147.75d? |  |  |  | 260d | finish no earlier than 2006-09-15 | R2 | 1576h | 394h | RANFS-MBMSImp | YoungDae Lee, LG | leego@lge.com | Rel-7 |  | MCC_RAN |  |  |
| 314 | 100 | FS on Performance Improvements in Small Cells using HSDPA/EDCH | 131d? | 2005-12-15 | 2006-06-15 |  |  |  |  |  | 326d | finish no earlier than 2006-06-15 | R4 | 1048h |  | SMALLCELLS | Marc Grant, Cingular | marc.grant@cingular.com | Rel-7 |  | MCC_RAN |  |  |
| 315 | 101 | FS on Further Improved Performance Requirements for UMTS/HSDPA UE (FDD) | 262d? | 2005-12-15 A | 2006-12-15 | 20% | 209.6d? |  |  |  | 195d | finish no earlier than 2006-12-15 | R4 | 2096h | 419.2h | RANFS-IC | Marc Grant, Cingular | marc.grant@cingular.com | Rel-7 |  | MCC_RAN |  |  |
| 316 | 102 | FS on the TCAPsec Gateway concept | 96d? | 2005-10-28 A | 2006-03-10 | 85% | 14.4d? | 2005-10-07 | 2006-03-17 | 116d? | 395d | finish no earlier than 2006-03-10 | C4 | 768h | 652.8h | SEC7-TCAP | Ulrich Wiehe, Siemens | Ulrich.wiehe@gksag.de | Rel-7 |  | Kimmo | 29.800 |  |
| 317 | 103 | Study of Customised Alerting Tone (CAT) Requirements | 191d? | 2005-10-07 A | 2006-06-30 | 20% | 152.8d? | 2005-10-07 | 2006-06-30 | 191d? | 315d | start no earlier than 2005-10-07 | S1 | 1528h | 305.6h | CAT | Feng Lingjuan, China Mobile | fenglingjuan@chinamobile.com | Rel-7 |  | Michael |  |  |
| 318 | 104 | Facilitating Machine to Machine Communication in GSM and UMTS (M2M) | 161d? | 2005-11-04 A | 2006-06-16 | 50% | 80.5d? | 2005-11-04 | 2006-06-16 | 161d? | 325d | finish no earlier than 2006-06-16 | S1 | 1288h | 644h | M2M | Juergen Merkel, Siemens AG |  | Rel-7 |  | Michael | 22.868 |  |
| 319 | 105 | SI on Scope of future FDD HSPA Evolution | 198d? | 2006-03-15 | 2006-12-15 |  |  |  |  |  | 195d | finish no earlier than 2006-12-15 | RP | 1584h |  | RANFS-HSPAEvo | Don Zelmer | don.zelmer@cingular.com | Rel-7 |  | MCC_RAN |  |  |
| 320 | 106 | **OAM&P Studies** | 336d? | 2005-09-02 A | 2006-12-15 | 29% | 238.27d? | 2004-02-16 | 2007-03-30 | 815d? | 195d |  | S5 | 33704h | 11709.6h | OAM7 | Christian TOCHE | toche@nortel.com | Rel-7 | TSG | Adrian |  |  |
| 321 | 106.1 | **Network Infrastructure Management** | 336d? | 2005-09-02 A | 2006-12-15 | 29% | 238.27d? | 2005-09-02 | 2006-12-22 | 341d? | 195d |  | S5 | 31016h | 9021.62h | OAM7-NIM |  |  | Rel-7 |  |  |  |  |
| 322 | 106.1.1 | IRP usage scenarios | 336d? | 2005-09-02 A | 2006-12-15 | 1% | 332.64d? | 2005-09-02 | 2005-12-07 | 69d? | 195d | finish no earlier than 2006-12-15 | S5 | 2688h | 26.88h | OAM7-NIM | Lucent |  | Rel-7 |  |  | new TR 32.8xy |  |
| 323 | 106.1.2 | Co-operative Element Management interface (CO-OP) | 336d? | 2005-09-02 A | 2006-12-15 | 75% | 84d? | 2005-09-02 | 2006-03-31 | 151d? | 195d | finish no earlier than 2006-12-15 | S5 | 2688h | 2016h | OAM7-NIM-COOP | Motorola |  | Rel-7 |  |  | new TR 32.8xy, 32.101 |  |
| 324 | 106.1.3 | Delta synchronization between IRP Manager and IRP Agent | 336d? | 2005-09-02 A | 2006-12-15 | 55% | 151.2d? | 2005-09-02 | 2005-12-07 | 69d? | 195d | finish no earlier than 2006-12-15 | S5 | 2688h | 1478.4h | OAM7-NIM | Siemens |  | Rel-7 |  |  | new TR 32.8xy, new TSs 32.111-n,32.60n; For n = 1 to 5 |  |
| 325 | 106.1.4 | Partial suspension of Itf-N during maintenance/testing | 336d? | 2005-09-02 A | 2006-12-15 | 50% | 168d? | 2005-09-02 | 2005-12-07 | 69d? | 195d | finish no earlier than 2006-12-15 | S5 | 2688h | 1344h | OAM7-NIM | Siemens |  | Rel-7 |  |  | new TR 32.8xy, new TSs 32.30n,32.60n,32.61n; For n = 1 to 5 |  |
| 326 | 106.1.5 | Advanced Alarming on Itf-N | 336d? | 2005-09-02 A | 2006-12-15 | 35% | 218.4d? | 2005-09-02 | 2006-06-30 | 216d? | 195d | finish no earlier than 2006-12-15 | S5 | 2688h | 940.8h | OAM7-NIM | Siemens |  | Rel-7 |  |  | new TR 32.8xy ; new TSs 32.111-n,32.30n; For n = 1 to 5 |  |
| 327 | 106.1.6 | Backward and Forward Compatibility of IRP systems | 336d? | 2005-09-02 A | 2006-12-15 | 10% | 302.4d? | 2005-09-02 | 2006-12-22 | 341d? | 195d | finish no earlier than 2006-12-15 | S5 | 2688h | 268.8h | OAM7-NIM-BFC | Ericsson |  | Rel-7 |  |  | new TR 32.805. new TS 32.15X |  |
| 328 | 106.1.7 | Study of Element Operations Systems Function (EOSF) definition | 336d? | 2005-09-02 A | 2006-12-15 | 15% | 285.6d? | 2005-09-02 | 2006-12-22 | 341d? | 195d | finish no earlier than 2006-12-15 | S5 | 2688h | 403.2h | OAM7-NIM- EOSF | China Mobile |  | Rel-7 |  |  | new TR 32.8xy |  |
| 329 | 106.1.8 | Study of SOAP/HTTP IRP Solution Sets | 336d? | 2005-09-02 A | 2006-12-15 | 20% | 268.8d? | 2005-09-02 | 2006-09-22 | 276d? | 195d | finish no earlier than 2006-12-15 | S5 | 2688h | 537.6h | OAM7-NIM-SOAP | Nortel |  | Rel-7 |  |  | new TR 32.8xy |  |
| 330 | 106.1.9 | Study of Itf-N Implementation Conformance Statement (ICS) template | 336d? | 2005-09-02 A | 2006-12-15 | 15% | 285.6d? | 2005-09-02 | 2006-09-22 | 276d? | 195d | finish no earlier than 2006-12-15 | S5 | 2688h | 403.2h | OAM7-NIM-ICS | China Mobile |  | Rel-7 |  |  | new TR 32.8xy |  |
| 331 | 106.1.10 | Study of IRP Information Model | 336d? | 2005-09-02 A | 2006-12-15 | 30% | 235.2d? | 2005-09-02 | 2006-09-22 | 276d? | 195d | finish no earlier than 2006-12-15 | S5 | 2688h | 806.4h | OAM7-NIM-IM | Motorola |  | Rel-7 |  |  | new TR 32.8xy |  |
| 332 | 106.1.11 | Study on SA5 MTOSI XML Harmonization | 181d? | 2006-04-07 A | 2006-12-15 | 1% | 179.19d? |  |  |  | 195d | finish no earlier than 2006-12-15 | S5 | 1448h | 14.48h | OAM7-NIM-XML | Nortel |  | Rel-7 |  |  | new TR 32.8xy |  |
| 333 | 107 | SI on AS-MRFC media server control protocol | 133d? | 2006-03-22 | 2006-09-22 |  |  |  |  |  | 255d | start no earlier than 2006-03-22 | C1 | 1064h |  | MRFC | Mark Syrett (Hewlett-Packard) |  | Rel-7 |  |  | New TR 24.880 |  |
| 334 | 108 | Study on IMS utilizing multicast bearer services | 193d? | 2006-03-22 | 2006-12-15 |  |  |  |  |  | 195d | finish no earlier than 2006-12-15 | S2 | 1544h |  |  | Fiona Zhu (Siemens AG) |  |  |  | Maurice |  |  |
| 335 | 109 | FS of using M2PA in 3GPP network | 193d? | 2006-03-22 | 2006-12-15 |  |  |  |  |  | 195d | start no earlier than 2006-03-22 | C4 | 1544h |  |  |  |  |  |  | Kimmo |  |  |

Notes:
- 306: Moved from Rel6
- 310: Study WI
- 311: Awaiting MCC SA3 input
- 316: Study WI / TR presented for information in CT#30
- 317: Awaiting MCC SA3 input

| ID | WBS | Task | Type | Duration | Start | Finish | Complete | Remaining | Baseline start | Baseline finish | Baseline duration | Total slack | Constraint | Resources | Work | Actual work | Text1 | Text6 | Text12 | Text3 | Text4 | Text5 | Text7 | Text8 |
| --- | --- | --- | --- | --- | --- | --- | --- | --- | --- | --- | --- | --- | --- | --- | --- | --- | --- | --- | --- | --- | --- | --- | --- | --- |
| 336 | 110 | **Deleted: FS on applicability of GALILEO for LCS** |  | 484d? | 2003-08-25 A | 2005-06-30 |  | 484d? | 2003-08-25 | 2005-06-30 | 484d? | 576d |  | S2 | 3872h | 1000h | Galileo | Rel-7 | SP-25 |  |  |  |  |  |
| 337 | 110.1 | Deleted - TR on Stage 2 | milestone | 0d? | 2005-06-30 A | 2005-06-30 A | 100% |  | 2005-06-30 | 2005-06-30 | 0d? |  | finish no earlier than 2005-06-30 | S2 |  |  | Galileo | Rel-7 | SP-25 |  |  |  |  |  |
| 338 | 110.2 | deleted - GERAN review of the TR | milestone | 0d? | 2003-08-25 | 2003-08-25 |  |  | 2003-08-25 | 2003-08-25 | 0d? | 1060d | finish no earlier than 2003-08-25 | GP |  |  | Galileo | Rel-7 | SP-26 |  |  |  |  |  |
| 339 | 16.7 | **Deleted - IMS Local services** |  | 1158d? | 2001-01-01 A | 2005-06-08 | 68% | 367.35d? | 2001-01-01 | 2005-06-08 | 1158d? | 592d |  | S2 | 13072h | 5192.02h | IMSLocal | Rel-7 | SP-28 | 23.228 |  |  |  |  |
| 340 | 16.7.1 | Deleted - Stage 2 |  | 325d | 2001-01-01 A | 2002-03-29 A | 100% |  | 2001-01-01 | 2002-03-29 | 325d |  | start no earlier than 2001-01-01 | S2 | 2600h | 2600h | IMSLocal | Rel-7 | SP-26 |  |  |  |  |  |
| 341 | 111.2 | Delete - Stage 3 for IMS Local services |  | 151d? | 2004-11-10 | 2005-06-08 |  |  | 2004-11-10 | 2005-06-08 | 151d? | 592d | finish no earlier than 2005-06-08 | C1 | 1208h |  | IMSLocal | Rel-7 | SP-25 |  | Keith Drage, Lucent | drage@lucent.com |  |  |
| 342 | 112 | Deleted - IMS Phase 3 | milestone | 0d? | 2005-06-08 A | 2005-06-08 A | 100% |  | 2005-06-08 | 2005-06-08 | 0d? |  | finish no earlier than 2005-06-08 | S2 |  |  |  | Rel-7 | SP-25 |  |  |  |  |  |
| 343 | 113 | Deleted - Improvements of Radio Interface | milestone | 0d? | 2004-09-15 A | 2004-09-15 A | 100% |  | 2004-09-15 | 2004-09-15 | 0d? |  | start no earlier than 2004-09-15 | RP |  |  | RInImp | Rel-7 | SP-24 |  |  | Rel-7 | TSG | Cesar |
| 344 | 114 | **Deleted: Generic User Profile Phase 2** |  | 234.4d | 2005-10-06 A | 2006-08-31 |  | 234.4d | 2005-10-06 | 2006-08-31 | 234.4d | 271.6d |  | C4 |  |  |  | Rel-7 | SP-27 |  |  |  |  | Gaby |
| 345 | 30.4 | Deleted - Stage 3 - Common objects | milestone | 0d | 2005-10-06 A | 2006-08-31 |  | 0d | 2005-10-06 | 2006-08-31 | 0d | 271.6d | finish no earlier than 2005-10-06 | C4 |  |  |  | Rel-7 | SP-27 | 24.241 |  |  | TSG | Gaby |

Notes:
- 340: DAB - Not yet required in SA2 as it exists in previous releases
- 343: Stage 2 description of Interim conclusion
- 344: Created at TSG#27 by A. Sultan because of the move to Rel-7 of "Common Objects".
- 345: No progress in CN4#26. This have to be moved to Rel-7. It was deleted from WID
